# ATLAS

Schedule from MS Project, 2010-03-01 to 2013-03-01.
microsoft

## Calendars

- Standard: Mon-Fri 08:00-12:00, 13:00-17:00; Sat-Sun off. Exceptions (off unless hours are given): 2010-06-19 08:00-12:00, 13:00-17:00.

## Resources

| Resource |
| --- |
| CEO |
| CTO |
| ADA |
| ACA |
| SE 3 |
| SE 4 |
| SY AD |
| SE 1 |
| SE 2 |
| LNG |
| SE 5 |
| SE 6 |
| BUA |
| ST 1 |
| ST 2 |
| SE 7 |
| IBL DCL |
| Tetracom |
| ICS PAS |
| Atlantis |
| ITD |
| UHH |
| UAIC |
| UniZD |
| DFKI |

## Schedule

| ID | WBS | Task | Duration | Start | Finish | Predecessors | Total slack | Free slack | Constraint | Resources | Work |
| --- | --- | --- | --- | --- | --- | --- | --- | --- | --- | --- | --- |
| 1 | 1 | **WP1 - Project Management** | 764d? | 2010-03-01 | 2013-01-30 |  | 22d |  |  |  | 11056h |
| 2 | 1.1 | **T1.1 Preparation of a revised detailed project plan** | 39d | 2010-03-01 | 2010-04-22 |  | 483d |  |  |  | 576h |
| 3 | 1.1.1 | Detailed Project Plan draft | 15d | 2010-03-01 | 2010-03-19 |  | 483d | 19d |  | Tetracom [200%] | 240h |
| 4 | 1.1.2 | Detailed Project Plan draft | 6d | 2010-03-01 | 2010-03-08 |  | 778d | 28d |  | ITD [83.1%]; IBL DCL [83.1%]; Atlantis [50%]; ICS PAS [67%]; UAIC; UHH | 232h |
| 5 | 1.1.3 | Detailed Project Plan draft review and finalization | 5d | 2010-04-16 | 2010-04-22 | 3 | 464d | 6d | start no earlier than 2010-04-16 | Tetracom | 40h |
| 6 | 1.1.4 | Detailed Project Plan draft review and finalization | 2d | 2010-04-16 | 2010-04-19 | 4 | 750d |  | start no earlier than 2010-04-16 | ITD [50%]; IBL DCL [50%]; Atlantis [50%]; ICS PAS [50%]; UHH; UAIC | 64h |
| 7 | 1.2 | **T1.2 Commercial agreement preparation** | 15d? | 2010-09-01 | 2010-09-21 |  | 638d |  |  |  | 608h |
| 8 | 1.2.1 | Commercial Agreement draft | 8d | 2010-09-01 | 2010-09-10 |  | 643d | 0d | start no earlier than 2010-09-01 | Tetracom [250%] | 160h |
| 9 | 1.2.2 | Commercial Agreement draft | 12d | 2010-09-01 | 2010-09-16 |  | 638d | 0d | start no earlier than 2010-09-01 | ITD | 96h |
| 10 | 1.2.3 | Commercial Agreement draft | 4d | 2010-09-01 | 2010-09-06 |  | 648d | 4d | start no earlier than 2010-09-01 | Atlantis | 32h |
| 11 | 1.2.4 | Commercial Agreement draft | 8d | 2010-09-01 | 2010-09-10 |  | 643d | 0d | start no earlier than 2010-09-01 | IBL DCL [12%]; ICS PAS [50.1%]; UAIC [75.1%]; UHH [50.1%]; UniZD | 184h |
| 12 | 1.2.5 | Commercial Agreement draft review and finalization | 2d | 2010-09-13 | 2010-09-14 | 8 | 643d |  | start no earlier than 2010-07-01 | Tetracom [250%] | 40h |
| 13 | 1.2.6 | Commercial Agreement draft review and finalization | 3d | 2010-09-17 | 2010-09-21 | 9 | 638d |  | start no earlier than 2010-09-13 | ITD | 24h |
| 14 | 1.2.7 | Commercial Agreement draft review and finalization | 1d? | 2010-09-13 | 2010-09-13 | 10 | 644d |  | start no earlier than 2010-09-13 | Atlantis | 8h |
| 15 | 1.2.8 | Commercial Agreement draft review and finalization | 2d | 2010-09-13 | 2010-09-14 | 11 | 643d |  | start no earlier than 2010-09-13 | IBL DCL [50%]; ICS PAS [50%]; UAIC; UHH; UniZD | 64h |
| 16 | 1.3 | **T1.3 Technical communication** | 756d | 2010-03-01 | 2013-01-18 |  | 30d |  |  |  | 536h |
| 17 | 1.3.1 | Technical communication | 756d | 2010-03-01 | 2013-01-18 |  | 30d |  |  | Tetracom [5.3%] | 320h |
| 18 | 1.3.2 | Technical communication | 756d | 2010-03-01 | 2013-01-18 |  | 30d |  | start no earlier than 2010-03-01 | IBL DCL [0.5%]; ICS PAS [0.8%]; UAIC [0.8%]; UHH [0.8%]; UniZD [0.8%] | 216h |
| 19 | 1.4 | **T1.4 Project coordination and management** | 764d | 2010-03-01 | 2013-01-30 |  | 22d |  |  |  | 5176h |
| 20 | 1.4.1 | Financial reports and accountant tasks | 756d | 2010-03-01 | 2013-01-18 |  | 30d |  | start no earlier than 2010-03-01 | Tetracom [23.8%] | 1440h |
| 21 | 1.4.2 | Financial reports and accountant tasks | 756d | 2010-03-01 | 2013-01-18 |  | 30d |  |  | IBL DCL [2.6%]; Atlantis [2%]; ICS PAS [3%] | 456h |
| 22 | 1.4.3 | Project coordination and management | 764d | 2010-03-01 | 2013-01-30 |  | 22d |  | start no earlier than 2010-03-01 | Tetracom [19.6%] | 1200h |
| 23 | 1.4.4 | Project coordination and management | 764d | 2010-03-01 | 2013-01-30 |  | 22d |  |  | IBL DCL [14.9%]; Atlantis [2.1%]; ICS PAS [4.1%]; UHH [6%]; UniZD [5%]; UAIC [2%] | 2080h |
| 24 | 1.5 | **T1.5 Project meetings** | 82d | 2010-03-01 | 2010-06-21 |  | 704d |  |  |  | 1064h |
| 25 | 1.5.1 | Kick-off meeting | 2d | 2010-04-26 | 2010-04-27 |  | 744d |  | start no earlier than 2010-04-26 | Tetracom [300%] | 48h |
| 26 | 1.5.2 | Kick-off meeting | 2d | 2010-04-26 | 2010-04-27 |  | 744d |  | start no earlier than 2010-04-26 | IBL DCL; Atlantis; ICS PAS; UniZD; UHH; UAIC; ITD | 112h |
| 27 | 1.5.3 | WP3 meeting in Zadar | 2d | 2010-06-07 | 2010-06-08 |  | 714d |  | start no earlier than 2010-06-07 | Tetracom [400%]; UniZD [200%] | 96h |
| 28 | 1.5.4 | WP5 and WP6 meeting in Vienna | 2d | 2010-06-19 | 2010-06-21 |  | 704d |  | start no earlier than 2010-06-19 | Tetracom [200%]; IBL DCL [50%]; Atlantis; ICS PAS [200%]; UHH [200%]; UAIC | 136h |
| 29 | 1.5.5 | Project Meetings | 24d | 2010-03-01 | 2010-04-01 |  | 762d |  |  | Tetracom [208.3%] | 400h |
| 30 | 1.5.6 | Project Meetings | 3d | 2010-03-01 | 2010-03-03 |  | 783d |  |  | IBL DCL | 24h |
| 31 | 1.5.7 | Project Meetings | 13d | 2010-03-01 | 2010-03-17 |  | 773d |  |  | Atlantis | 104h |
| 32 | 1.5.8 | Project Meetings | 4d | 2010-03-01 | 2010-03-04 |  | 782d |  |  | ICS PAS | 32h |
| 33 | 1.5.9 | Project Meetings | 4d | 2010-03-01 | 2010-03-04 |  | 782d |  |  | UniZD | 32h |
| 34 | 1.5.10 | Project Meetings | 4d | 2010-03-01 | 2010-03-04 |  | 782d |  |  | UHH | 32h |
| 35 | 1.5.11 | Project Meetings | 6d | 2010-03-01 | 2010-03-08 |  | 780d |  |  | UAIC | 48h |

| ID | WBS | Task | Duration | Start | Finish | Predecessors | Total slack | Free slack | Constraint | Resources | Work |
| --- | --- | --- | --- | --- | --- | --- | --- | --- | --- | --- | --- |
| 36 | 1.6 | **T1.6 Work on contractual deliverables** | 764d | 2010-03-01 | 2013-01-30 |  | 22d |  |  |  | 3096h |
| 37 | 1.6.1 | Resource monitoring | 756d | 2010-03-01 | 2013-01-18 |  | 30d |  | start no earlier than 2010-03-01 | Tetracom [6%] | 360h |
| 38 | 1.6.2 | Quality control and workplan monitoring | 764d | 2010-03-01 | 2013-01-30 |  | 22d |  | start no earlier than 2010-03-01 | Tetracom [6%] | 368h |
| 39 | 1.6.3 | Reporting to the EU Commission | 756d | 2010-03-01 | 2013-01-18 |  | 30d |  | start no earlier than 2010-03-01 | Tetracom [33.1%] | 2000h |
| 40 | 1.6.4 | Reporting to the EU Commission | 756d | 2010-03-01 | 2013-01-18 |  | 30d |  |  | Atlantis [1.2%]; ICS PAS [1.2%]; UniZD [1.2%]; UHH [1.2%]; UAIC [1.2%] | 368h |
| 41 | 2 | **WP2 - Software Specification, Implementation and Deployment** | 381d? | 2010-04-01 | 2011-09-14 |  | 333d |  |  |  | 22608h |
| 42 | 2.1 | **T2.1 Specification of the linguistic framework** | 33d | 2010-04-01 | 2010-05-17 |  | 333d |  |  |  | 1016h |
| 43 | 2.1.1 | Draft of the linguistic framework specification | 20d | 2010-04-01 | 2010-04-28 |  | 333d | 0d | start no earlier than 2010-04-01 | Tetracom [200%] | 320h |
| 44 | 2.1.2 | Draft of the linguistic framework specification | 20d | 2010-04-01 | 2010-04-28 |  | 734d | 0d | start no earlier than 2010-04-01 | IBL DCL [10%]; Atlantis [25%]; UAIC [10%]; UniZD; UHH [50%]; ICS PAS [30%] | 360h |
| 45 | 2.1.3 | Review of the lingusitic framework specification | 3d | 2010-04-29 | 2010-05-03 | 43 | 333d | 0d |  | Tetracom | 24h |
| 46 | 2.1.4 | Review of the linguistic framework specification | 5d | 2010-04-29 | 2010-05-05 | 44 | 734d | 0d | start no earlier than 2010-04-29 | IBL DCL [80%]; Atlantis [40%]; ICS PAS [40%]; UAIC [40%]; UniZD; UHH [40%] | 136h |
| 47 | 2.1.5 | Final version of the linguistic framework specification | 10d | 2010-05-04 | 2010-05-17 | 45 | 333d | 33d |  | Tetracom | 80h |
| 48 | 2.1.6 | Final version of the linguistic framework specification | 4d | 2010-05-06 | 2010-05-11 | 46 | 734d |  | start no earlier than 2010-05-04 | IBL DCL [50%]; UniZD; UHH [50%]; Atlantis [25%]; ICS PAS [50%]; UAIC [25%] | 96h |
| 49 | 2.2 | **T2.2 Use case specifications** | 20d? | 2010-05-03 | 2010-05-28 |  | 458d | 0d |  |  | 1144h |
| 50 | 2.2.1 | Use case specifications | 20d | 2010-05-03 | 2010-05-28 |  | 458d |  | start no earlier than 2010-05-03 | ITD [315%] | 504h |
| 51 | 2.2.2 | Use case specifications | 20d? | 2010-05-03 | 2010-05-28 | 5 | 458d |  | start no earlier than 2010-05-01 | Tetracom | 160h |
| 52 | 2.2.3 | Use case specifications | 10d | 2010-05-03 | 2010-05-14 |  | 468d |  | start no earlier than 2010-05-03 | IBL DCL [80%]; Atlantis [130%]; ICS PAS; UniZD [190%]; UHH | 480h |
| 53 | 2.3 | **T2.3 Refinement of software requirements** | 10d | 2010-05-31 | 2010-06-11 | 49 | 458d | 0d |  |  | 1064h |
| 54 | 2.3.1 | Refinement of software requirements | 10d | 2010-05-31 | 2010-06-11 |  | 458d |  |  | ITD [420%] | 336h |
| 55 | 2.3.2 | Refinement of software requirements | 10d | 2010-05-31 | 2010-06-11 |  | 458d | 0d | start no earlier than 2009-10-18 | Tetracom [200%] | 160h |
| 56 | 2.3.3 | Refinement of software requirements | 10d | 2010-05-31 | 2010-06-11 |  | 458d |  |  | IBL DCL [40%]; Atlantis [210%]; ICS PAS; UAIC; UniZD [160%]; UHH | 568h |
| 57 | 2.4 | **T2.4 Software specification** | 96d | 2010-06-14 | 2010-10-22 | 53 | 458d |  |  |  | 2024h |
| 58 | 2.4.1 | High-level software design specification | 18d | 2010-06-14 | 2010-07-06 | 55 | 458d | 0d | start no earlier than 2009-11-15 | Tetracom [300%] | 432h |
| 59 | 2.4.2 | High-level software design specification | 18d | 2010-06-14 | 2010-07-06 |  | 693d |  |  | ITD [116.7%] | 168h |
| 60 | 2.4.3 | Detailed software specification draft | 50d | 2010-07-07 | 2010-09-14 | 58 | 633d | 0d | start no earlier than 2009-11-22 | Tetracom [126%] | 504h |
| 61 | 2.4.4 | Detailed software specification draft | 12d | 2010-07-07 | 2010-07-22 | 58 | 681d |  |  | Atlantis [33.1%]; UAIC [200.2%]; UHH [133%]; UniZD [92%] | 440h |
| 62 | 2.4.5 | Review of the software specification draft | 37d | 2010-08-05 | 2010-09-24 |  | 620d | 5d | start no earlier than 2010-08-05 | Tetracom [59.5%] | 176h |
| 63 | 2.4.6 | Review of the software specification draft | 10d | 2010-09-15 | 2010-09-28 | 60 | 633d |  |  | ITD [210%] | 168h |
| 64 | 2.4.7 | Review of the software specification draft | 2d | 2010-09-15 | 2010-09-16 | 60 | 641d |  |  | Atlantis | 16h |
| 65 | 2.4.8 | Final version of the detailed software specification | 15d | 2010-10-04 | 2010-10-22 | 62 | 615d |  | start no earlier than 2010-10-04 | Tetracom | 120h |

| ID | WBS | Task | Duration | Start | Finish | Predecessors | Total slack | Free slack | Constraint | Resources | Work |
| --- | --- | --- | --- | --- | --- | --- | --- | --- | --- | --- | --- |
| 66 | 2.5 | **T2.5 i-Publisher - implementation and deployment** | 159d | 2010-06-14 | 2011-01-19 |  | 403d | 0d |  |  | 3552h |
| 67 | 2.5.1 | Evaluation of visualization tools and libraries; Prototyping | 25d | 2010-07-08 | 2010-08-11 | 58 | 457d | 0d | start no earlier than 2010-07-08 | Tetracom [200%] | 400h |
| 68 | 2.5.2 | Implementation of i-Publisher visual components | 40d | 2010-08-12 | 2010-10-06 | 67 | 457d | 0d |  | Tetracom [300%] | 960h |
| 69 | 2.5.3 | Technical review of ATLAS and i-Publisher | 21d | 2010-10-07 | 2010-11-04 | 68 | 457d |  |  | ITD [100.6%]; UAIC [47.3%]; UHH [5%]; UniZD [9%] | 272h |
| 70 | 2.5.4 | Software adjustments (in resp. to the technical review) | 25d | 2010-11-04 | 2010-12-08 |  | 433d |  | start no earlier than 2010-11-04 | Tetracom [240%] | 480h |
| 71 | 2.5.5 | Integration of i-Publisher in ATLAS | 40d | 2010-11-25 | 2011-01-19 |  | 403d |  | start no earlier than 2010-11-25 | Tetracom [300%] | 960h |
| 72 | 2.5.6 | Test deployment of i-Publisher | 5d | 2011-01-13 | 2011-01-19 |  | 403d | 0d | start no earlier than 2011-01-13 | Tetracom [200%] | 80h |
| 73 | 2.5.7 | English linguistic adjustments and improvements | 25d | 2010-06-14 | 2010-07-15 |  | 537d |  | start no earlier than 2010-06-14 | Tetracom [200%] | 400h |
| 74 | 2.6 | **T2.6 i-Librarian - implementation and deployment** | 26d? | 2010-09-23 | 2010-10-28 |  | 462d | 59d |  |  | 640h |
| 75 | 2.6.1 | Implementation of an i-Librarian prototype with i-Publisher | 10d? | 2010-09-23 | 2010-10-06 |  | 462d | 0d | start no earlier than 2010-09-23 | Tetracom [300%] | 240h |
| 76 | 2.6.2 | Technical review of the i-Librarian prototype | 3d | 2010-10-07 | 2010-10-11 | 75 | 462d | 0d |  | ITD [367.3%]; UAIC [333.6%]; UHH [33%]; UniZD [66.1%] | 192h |
| 77 | 2.6.3 | Software adjustments (in resp. to the technical review) | 10d | 2010-10-12 | 2010-10-25 | 76 | 462d | 0d |  | Tetracom [200%] | 160h |
| 78 | 2.6.4 | Test deployment of i-Librarian | 3d | 2010-10-26 | 2010-10-28 | 77 | 462d | 69d |  | Tetracom [200%] | 48h |
| 79 | 2.7 | **T2.7 EUDocLib - implementation and deployment** | 41d | 2010-09-23 | 2010-11-18 |  | 447d | 44d |  |  | 760h |
| 80 | 2.7.1 | Implementation of an EUDocLib prototype with i-Publisher | 25d | 2010-09-23 | 2010-10-27 |  | 460d | 0d | start no earlier than 2010-09-23 | Tetracom [208%] | 416h |
| 81 | 2.7.2 | EUDocLib technical review | 3d | 2010-10-28 | 2010-11-01 | 80 | 460d |  |  | ITD [367.3%]; UAIC [166.3%]; UHH [33%] | 136h |
| 82 | 2.7.3 | Software adjustments (in resp. to the technical review) | 20d | 2010-10-19 | 2010-11-15 |  | 450d |  | start no earlier than 2010-10-19 | Tetracom | 160h |
| 83 | 2.7.4 | Test deployment of EUDocLib | 13d | 2010-11-02 | 2010-11-18 |  | 447d | 59d | start no earlier than 2010-11-02 | Tetracom [46.2%] | 48h |
| 84 | 2.8 | **T2.8 Technical documentation** | 180d | 2011-01-06 | 2011-09-14 |  | 382d |  |  |  | 6608h |
| 85 | 2.8.1 | ATLAS technical documentation draft | 130d | 2011-01-06 | 2011-07-06 |  | 432d |  | start no earlier than 2011-01-06 | Tetracom [384.6%] | 4000h |
| 86 | 2.8.2 | ATLAS technical documentation draft | 4d | 2011-01-06 | 2011-01-11 |  | 558d |  | start no earlier than 2011-01-06 | UAIC [125%]; UHH [250%]; UniZD [275%] | 208h |
| 87 | 2.8.3 | i-Publisher technical documentation draft | 100d | 2011-02-17 | 2011-07-06 |  | 432d |  | start no earlier than 2011-02-17 | Tetracom | 800h |
| 88 | 2.8.4 | i-Librarian and EUDocLib technical documentation draft | 129d | 2011-03-18 | 2011-09-14 |  | 382d |  | start no earlier than 2011-03-18 | Tetracom [155%] | 1600h |
| 89 | 2.9 | **T2.9 User guides** | 213d | 2010-08-24 | 2011-06-16 |  | 446d |  |  |  | 5480h |
| 90 | 2.9.1 | ATLAS user guide draft | 100d | 2010-08-24 | 2011-01-10 |  | 559d |  | start no earlier than 2010-08-24 | Tetracom [200%] | 1600h |
| 91 | 2.9.2 | ATLAS user guide draft | 15d | 2010-08-24 | 2010-09-13 |  | 644d |  | start no earlier than 2010-08-24 | ICS PAS [201.1%]; IBL DCL [26.1%]; UAIC [33.2%]; UHH; UniZD [66.1%] | 512h |
| 92 | 2.9.3 | i-Publisher user guide draft | 102d | 2010-09-01 | 2011-01-20 |  | 551d |  | start no earlier than 2010-09-01 | Tetracom [154.9%] | 1264h |
| 93 | 2.9.4 | i-Librarian user guide draft | 109d | 2010-10-25 | 2011-03-24 |  | 506d |  | start no earlier than 2010-10-25 | Tetracom [103.7%] | 904h |
| 94 | 2.9.5 | EUDocLib user guide draft | 124d | 2010-12-27 | 2011-06-16 |  | 446d |  | start no earlier than 2010-12-27 | Tetracom [121%] | 1200h |

| ID | WBS | Task | Duration | Start | Finish | Predecessors | Total slack | Free slack | Constraint | Resources | Work |
| --- | --- | --- | --- | --- | --- | --- | --- | --- | --- | --- | --- |
| 95 | 2.10 | **M1** | 20d | 2011-01-20 | 2011-02-16 | 66, 74, 79 | 403d | 0d |  |  | 320h |
| 96 | 2.10.1 | i-Publisher pilot deployment | 10d | 2011-01-20 | 2011-02-02 | 72 | 403d | 0d | start no earlier than 2010-06-27 | Tetracom [200%] | 160h |
| 97 | 2.10.2 | i-Librarian pilot deployment | 5d | 2011-02-03 | 2011-02-09 | 96, 78 | 403d | 0d | start no earlier than 2010-07-25 | Tetracom [200%] | 80h |
| 98 | 2.10.3 | EUDocLib pilot deployment | 5d | 2011-02-10 | 2011-02-16 | 97, 83 | 403d |  | start no earlier than 2010-08-01 | Tetracom [200%] | 80h |
| 99 | 3 | **WP3 - Automatic Text Categorization** | 406d? | 2010-07-01 | 2012-01-19 |  | 291d |  |  |  | 12536h |
| 100 | 3.1 | **T3.1 Prototype and integration** | 272d? | 2010-07-01 | 2011-07-15 |  | 280d | 119d |  |  | 2264h |
| 101 | 3.1.1 | Implementation of a categorization tool (incl. documentation) | 52d? | 2010-07-01 | 2010-09-10 |  | 500d |  | start no earlier than 2010-07-01 | IBL DCL | 416h |
| 102 | 3.1.2 | Implementation of a categorization tool (incl. documentation) | 25d | 2010-07-01 | 2010-08-04 |  | 527d |  | start no earlier than 2010-07-01 | ICS PAS | 200h |
| 103 | 3.1.3 | Implementation of a categorization tool (incl. documentation) | 55d? | 2010-07-01 | 2010-09-15 |  | 408d | 86d | start no earlier than 2010-07-01 |  |  |
| 104 | 3.1.4 | Technical review of the categorization tool | 20d | 2011-03-07 | 2011-04-01 | 128, 129, 130, 131, 132, 133 | 322d | 41d | start no earlier than 2010-08-29 | Tetracom | 160h |
| 105 | 3.1.5 | Technical review of the categorization tool | 42d | 2011-02-03 | 2011-04-01 |  | 355d |  | start no earlier than 2011-02-03 | IBL DCL | 336h |
| 106 | 3.1.6 | Technical review of the categorization tool | 25d | 2011-02-28 | 2011-04-01 |  | 355d |  | start no earlier than 2011-02-28 | ICS PAS | 200h |
| 107 | 3.1.7 | Feedback in the tool selection process | 21d | 2010-10-01 | 2010-10-29 |  | 465d |  | start no earlier than 2010-10-01 | Atlantis [185.7%] | 312h |
| 108 | 3.1.8 | Integration of the categorization tool in ATLAS | 13d | 2011-06-29 | 2011-07-15 | 140, 141, 142, 143, 144, 145, 135 | 280d | 43d | start no earlier than 2011-06-29 | Tetracom | 104h |
| 109 | 3.1.9 | Integration of the categorization tool in ATLAS | 21d | 2011-06-17 | 2011-07-15 |  | 280d |  | start no earlier than 2011-06-17 | IBL DCL [200%] | 336h |
| 110 | 3.1.10 | Integration of the categorization tool in ATLAS | 15d | 2011-06-27 | 2011-07-15 |  | 280d |  | start no earlier than 2011-06-27 | ICS PAS [166.7%] | 200h |
| 111 | 3.2 | **T3.2 Fine tuning to specific languages** | 152d? | 2010-10-29 | 2011-05-30 |  | 280d | 0d |  |  | 3848h |
| 112 | 3.2.1 | **Bulgarian** | 66d | 2010-10-29 | 2011-01-28 |  | 366d |  |  | IBL DCL | 1440h |
| 113 | 3.2.1.1 | Experiments with the predefined classification for Bulgarian | 5d | 2010-10-29 | 2010-11-04 |  | 370d | 0d | start no earlier than 2010-10-29 | IBL DCL | 40h |
| 114 | 3.2.1.2 | Definition of common set of language resources and tools (ATLAS BLARK) | 3d | 2010-11-05 | 2010-11-09 | 113 | 370d | 0d | start no earlier than 2010-09-20 | IBL DCL | 24h |
| 115 | 3.2.1.3 | Specification of the scope and functionalities for the ATLAS BLARK | 2d | 2010-11-10 | 2010-11-11 | 114 | 370d | 0d | start no earlier than 2010-09-23 | IBL DCL | 16h |
| 116 | 3.2.1.4 | Definition of an unified tagset: attributes and values (such as to support the work in all project WPs) | 5d | 2010-11-12 | 2010-11-18 | 115 | 370d | 0d | start no earlier than 2010-09-27 | IBL DCL | 40h |
| 117 | 3.2.1.5 | Definition of the subset of attributes and values for the purposes of text categorization | 5d | 2010-11-19 | 2010-11-25 | 116 | 370d | 0d | start no earlier than 2010-10-04 | IBL DCL | 40h |
| 118 | 3.2.1.6 | Adaptation of existing language resources for Bulgarian for the purposes of text categorization | 21d | 2010-11-26 | 2010-12-24 | 117 | 391d |  | start no earlier than 2010-11-26 | IBL DCL | 168h |
| 119 | 3.2.1.7 | Development of new language resources for Bulgarian for the purposes of text categorization | 21d | 2010-11-26 | 2010-12-24 | 117 | 370d | 0d | start no earlier than 2010-11-26 | IBL DCL [247.6%] | 416h |
| 120 | 3.2.1.8 | Linguistic preprocessing of Bulgarian documents - fine tuning | 10d | 2010-12-27 | 2011-01-07 | 119 | 370d | 4d | start no earlier than 2010-12-27 | IBL DCL | 80h |
| 121 | 3.2.1.9 | Linguistic processing of Bulgarian documents - fine tuning | 11d | 2011-01-14 | 2011-01-28 | 120 | 366d |  | start no earlier than 2011-01-14 | IBL DCL | 88h |

| ID | WBS | Task | Duration | Start | Finish | Predecessors | Total slack | Free slack | Constraint | Resources | Work |
| --- | --- | --- | --- | --- | --- | --- | --- | --- | --- | --- | --- |
| 122 | 3.2.2 | **Greek** | 106d | 2011-01-03 | 2011-05-30 |  | 280d |  |  | Atlantis | 1232h |
| 123 | 3.2.2.1 | Identification of adaptation requirements for GR | 21d | 2011-01-03 | 2011-01-31 |  | 365d |  | start no earlier than 2011-01-03 | Atlantis [47.6%] | 80h |
| 124 | 3.2.2.2 | Collection of docs to be used for GR categorisation testing | 21d | 2011-02-01 | 2011-03-01 |  | 344d |  | start no earlier than 2011-02-01 | Atlantis [47.6%] | 80h |
| 125 | 3.2.2.3 | Implementation of adaptations for GR | 63d | 2011-02-01 | 2011-04-28 |  | 302d |  | start no earlier than 2011-02-01 | Atlantis [31.7%] | 160h |
| 126 | 3.2.2.4 | Testing and re-engineering of GR categorisation | 42d | 2011-04-01 | 2011-05-30 |  | 280d |  | start no earlier than 2011-04-01 | Atlantis [19%] | 64h |
| 127 | 3.2.3 | Polish | 30d | 2011-01-14 | 2011-02-24 |  | 347d |  | start no earlier than 2011-01-14 | ICS PAS [250%] | 600h |
| 128 | 3.2.4 | Bulgarian | 6d | 2011-01-14 | 2011-01-21 | 103 | 322d | 0d | start no earlier than 2011-01-14 | Tetracom [200%] | 96h |
| 129 | 3.2.5 | Croatian | 6d | 2011-01-24 | 2011-01-31 | 128 | 322d | 0d | start no earlier than 2011-01-14 | Tetracom [200%] | 96h |
| 130 | 3.2.6 | German | 6d | 2011-02-01 | 2011-02-08 | 129 | 322d | 0d | start no earlier than 2011-01-14 | Tetracom [200%] | 96h |
| 131 | 3.2.7 | Greek | 6d | 2011-02-09 | 2011-02-16 | 130 | 322d | 0d | start no earlier than 2011-01-14 | Tetracom [200%] | 96h |
| 132 | 3.2.8 | Polish | 6d | 2011-02-17 | 2011-02-24 | 131 | 322d | 0d | start no earlier than 2011-01-14 | Tetracom [200%] | 96h |
| 133 | 3.2.9 | Romanian | 6d? | 2011-02-25 | 2011-03-04 | 132 | 322d | 0d | start no earlier than 2011-01-14 | Tetracom [200%] | 96h |
| 134 | 3.3 | **T3.3 Software adjustments (in resp. to technical reviews)** | 21d | 2011-05-31 | 2011-06-28 | 111 | 280d | 27d |  |  | 3336h |
| 135 | 3.3.1 | **Bulgarian** | 21d | 2011-05-31 | 2011-06-28 |  | 280d | 0d |  | IBL DCL | 912h |
| 136 | 3.3.1.1 | Definition of unified technical specification (functionalities and implementation) for the language tools | 5d | 2011-05-31 | 2011-06-06 |  | 280d | 0d | start no earlier than 2011-04-04 | IBL DCL [160%] | 64h |
| 137 | 3.3.1.2 | Definition of technical specification (functionalities and implementation) for the language tools | 3d | 2011-06-07 | 2011-06-09 | 136 | 280d | 0d | start no earlier than 2011-04-04 | IBL DCL [166.7%] | 40h |
| 138 | 3.3.1.3 | Adaptation of existing language tools for Bulgarian for the purposes of text categorization | 10d | 2011-06-10 | 2011-06-23 | 137 | 283d |  | start no earlier than 2011-04-04 | IBL DCL [300%] | 240h |
| 139 | 3.3.1.4 | Development of new language tools for Bulgarian for the purposes of text categorization | 13d | 2011-06-10 | 2011-06-28 | 137 | 280d |  | start no earlier than 2011-04-04 | IBL DCL [384.6%] | 400h |
| 140 | 3.3.2 | Croatian | 20d | 2011-05-31 | 2011-06-27 | 104 | 281d | 1d | start no earlier than 2010-10-17 | UniZD [350%] | 560h |
| 141 | 3.3.3 | German | 20d | 2011-05-31 | 2011-06-27 | 104 | 281d | 1d | start no earlier than 2010-10-17 | UHH [200%] | 320h |
| 142 | 3.3.4 | Greek | 20d | 2011-05-31 | 2011-06-27 | 104 | 281d | 1d | start no earlier than 2010-10-17 | Atlantis [140%] | 224h |
| 143 | 3.3.5 | Polish | 20d | 2011-05-31 | 2011-06-27 | 104 | 281d | 1d | start no earlier than 2010-10-17 | ICS PAS [425%] | 680h |
| 144 | 3.3.6 | Romanian | 20d | 2011-05-31 | 2011-06-27 | 104 | 281d | 1d | start no earlier than 2010-10-17 | UAIC [125%] | 200h |
| 145 | 3.3.7 | English | 20d | 2011-06-01 | 2011-06-28 | 104 | 280d | 0d | start no earlier than 2011-06-01 | Tetracom [275%] | 440h |

| ID | WBS | Task | Duration | Start | Finish | Predecessors | Total slack | Free slack | Constraint | Resources | Work |
| --- | --- | --- | --- | --- | --- | --- | --- | --- | --- | --- | --- |
| 146 | 3.4 | **T3.4 Documentation** | 51d | 2011-08-05 | 2011-10-14 | 134 | 360d |  |  |  | 2264h |
| 147 | 3.4.1 | ATLAS technical documentation update | 41d | 2011-08-05 | 2011-09-30 |  | 365d | 0d | start no earlier than 2011-08-05 | Tetracom [73.2%] | 240h |
| 148 | 3.4.2 | ATLAS technical documentation update | 30d | 2011-08-05 | 2011-09-15 |  | 381d |  | start no earlier than 2011-08-05 | Atlantis [43.1%]; ICS PAS [217.4%]; UniZD [90.2%]; UHH [113.2%]; UAIC [116.2%] | 1392h |
| 149 | 3.4.3 | User guides update | 22d | 2011-09-15 | 2011-10-14 | 108 | 360d |  | start no earlier than 2011-09-15 | Tetracom [200%] | 352h |
| 150 | 3.4.4 | User guides update | 14d | 2011-09-15 | 2011-10-04 |  | 368d |  | start no earlier than 2011-09-15 | IBL DCL | 112h |
| 151 | 3.4.5 | Documentation review | 5d | 2011-10-03 | 2011-10-07 | 147 | 365d |  | start no earlier than 2011-01-16 | Tetracom [200%] | 80h |
| 152 | 3.4.6 | Documentation review | 11d | 2011-09-23 | 2011-10-07 |  | 365d |  | start no earlier than 2011-09-23 | IBL DCL | 88h |
| 153 | 3.5 | **M2** | 15d | 2011-12-30 | 2012-01-19 | 100, 234 | 161d | 0d |  |  | 824h |
| 154 | 3.5.1 | Launch of i-Publisher with all project languages | 5d | 2011-12-30 | 2012-01-05 |  | 161d | 0d | start no earlier than 2011-12-30 | Tetracom [200%] | 80h |
| 155 | 3.5.2 | Launch of i-Publisher with all project languages | 5d | 2011-12-30 | 2012-01-05 |  | 161d | 0d |  | IBL DCL [140%]; UniZD [200%]; UHH [160%] | 200h |
| 156 | 3.5.3 | Launch of i-Librarian with all project languages | 5d | 2012-01-06 | 2012-01-12 | 154 | 161d | 0d | start no earlier than 2011-12-26 | Tetracom [200%] | 80h |
| 157 | 3.5.4 | Launch of i-Librarian with all project languages | 5d | 2012-01-06 | 2012-01-12 | 155 | 161d | 0d | start no earlier than 2012-01-06 | IBL DCL [140%]; UniZD [200%]; UHH [160%] | 200h |
| 158 | 3.5.5 | Launch of EUDocLib with all project languages | 5d | 2012-01-13 | 2012-01-19 | 156 | 161d |  | start no earlier than 2011-12-26 | Tetracom [200%] | 80h |
| 159 | 3.5.6 | Launch of EUDocLib with all project languages | 5d | 2012-01-13 | 2012-01-19 | 157 | 161d |  | start no earlier than 2012-01-13 | IBL DCL [160%]; UniZD [180%]; UHH [120%] | 184h |
| 160 | 4 | **WP4 - Language Processing Chains (LPC)** | 431d? | 2010-07-01 | 2012-02-23 | 47 | 266d |  |  |  | 32592h |
| 161 | 4.1 | **T4.1 Implementation of LPCs for the project languages** | 332d? | 2010-07-01 | 2011-10-07 |  | 164d | 0d |  |  | 23992h |
| 162 | 4.1.1 | **Preparation of the test plan** | 29d | 2010-07-01 | 2010-08-10 |  | 307d | 0d |  | ICS PAS | 696h |
| 163 | 4.1.1.1 | Detailed test plan | 20d | 2010-07-01 | 2010-07-28 |  | 307d | 0d | start no earlier than 2010-07-01 | ICS PAS [200%] | 320h |
| 164 | 4.1.1.2 | Review of the test plan | 5d | 2010-07-29 | 2010-08-04 | 163 | 307d | 0d | start no earlier than 2010-07-01 | ICS PAS [200%] | 80h |
| 165 | 4.1.1.3 | Final version of the test plan | 4d | 2010-08-05 | 2010-08-10 | 164 | 307d |  | start no earlier than 2010-07-01 | ICS PAS [200%] | 64h |
| 166 | 4.1.2 | **Integration of the chain for Bulgarian** | 141d | 2010-07-01 | 2011-01-13 |  | 330d | 166d |  | IBL DCL | 3120h |
| 167 | 4.1.2.1 | Integration of the tokenizer | 20d | 2010-07-01 | 2010-07-28 |  | 330d | 0d | start no earlier than 2010-07-01 | IBL DCL [175%] | 280h |
| 168 | 4.1.2.2 | Integration of the lemmatizer | 20d | 2010-07-29 | 2010-08-25 | 167 | 330d | 0d | start no earlier than 2010-07-01 | IBL DCL [175%] | 280h |
| 169 | 4.1.2.3 | Integration of the sentence splitter | 20d | 2010-08-26 | 2010-09-22 | 168 | 330d | 0d | start no earlier than 2010-07-01 | IBL DCL [175%] | 280h |
| 170 | 4.1.2.4 | Integration of the POS tagger | 20d | 2010-09-23 | 2010-10-20 | 169 | 330d | 0d | start no earlier than 2010-07-01 | IBL DCL [175%] | 280h |
| 171 | 4.1.2.5 | Integration of the NP extractor | 20d | 2010-10-21 | 2010-11-17 | 170 | 330d | 0d | start no earlier than 2010-07-01 | IBL DCL [175%] | 280h |
| 172 | 4.1.2.6 | Integration of the NE recognizer | 20d | 2010-11-18 | 2010-12-15 | 171 | 330d | 0d | start no earlier than 2010-07-01 | IBL DCL [175%] | 280h |
| 173 | 4.1.2.7 | Testing and improvement of the Bulgarian LPCs | 14d | 2010-12-16 | 2011-01-04 | 172 | 330d | 0d |  | IBL DCL | 112h |
| 174 | 4.1.2.8 | Integration tests | 7d | 2011-01-05 | 2011-01-13 | 173 | 330d |  | start no earlier than 2010-07-01 | ICS PAS [357.1%] | 200h |

| ID | WBS | Task | Duration | Start | Finish | Predecessors | Total slack | Free slack | Constraint | Resources | Work |
| --- | --- | --- | --- | --- | --- | --- | --- | --- | --- | --- | --- |
| 175 | 4.1.3 | **Integration of the chain for Croatian** | 126d | 2010-07-01 | 2010-12-23 |  | 345d | 181d |  | UniZD | 2984h |
| 176 | 4.1.3.1 | Integration of the tokenizer | 20d | 2010-07-01 | 2010-07-28 |  | 345d | 0d | start no earlier than 2010-07-01 | UniZD [185%] | 296h |
| 177 | 4.1.3.2 | Integration of the lemmatizer | 20d | 2010-07-29 | 2010-08-25 | 176 | 345d | 0d | start no earlier than 2010-07-01 | UniZD [185%] | 296h |
| 178 | 4.1.3.3 | Integration of the sentence splitter | 20d | 2010-08-26 | 2010-09-22 | 177 | 345d | 0d | start no earlier than 2010-07-01 | UniZD [185%] | 296h |
| 179 | 4.1.3.4 | Integration of the POS tagger | 20d | 2010-09-23 | 2010-10-20 | 178 | 345d | 0d | start no earlier than 2010-07-01 | UniZD [185%] | 296h |
| 180 | 4.1.3.5 | Integration of the NP extractor | 20d | 2010-10-21 | 2010-11-17 | 179 | 345d | 0d | start no earlier than 2010-07-01 | UniZD [185%] | 296h |
| 181 | 4.1.3.6 | Integration of the NE recognizer | 20d | 2010-11-18 | 2010-12-15 | 180 | 345d | 0d | start no earlier than 2010-07-01 | UniZD [185%] | 296h |
| 182 | 4.1.3.7 | Integration tests | 6d | 2010-12-16 | 2010-12-23 | 181 | 345d |  | start no earlier than 2010-07-01 | ICS PAS [416.7%] | 200h |
| 183 | 4.1.4 | **Integration of the chain for German** | 127d | 2010-07-01 | 2010-12-24 |  | 344d | 180d |  | UHH | 2936h |
| 184 | 4.1.4.1 | Integration of the tokenizer | 20d | 2010-07-01 | 2010-07-28 |  | 344d | 0d | start no earlier than 2010-07-01 | UHH [175%] | 280h |
| 185 | 4.1.4.2 | Integration of the lemmatizer | 20d | 2010-07-29 | 2010-08-25 | 184 | 344d | 0d | start no earlier than 2010-07-01 | UHH [175%] | 280h |
| 186 | 4.1.4.3 | Integration of the sentence splitter | 20d | 2010-08-26 | 2010-09-22 | 185 | 344d | 0d | start no earlier than 2010-07-01 | UHH [175%] | 280h |
| 187 | 4.1.4.4 | Integration of the POS tagger | 20d | 2010-09-23 | 2010-10-20 | 186 | 344d | 0d | start no earlier than 2010-07-01 | UHH [175%] | 280h |
| 188 | 4.1.4.5 | Integration of the NP extractor | 20d | 2010-10-21 | 2010-11-17 | 187 | 344d | 0d | start no earlier than 2010-07-01 | UHH [200%] | 320h |
| 189 | 4.1.4.6 | Integration of the NE recognizer | 21d | 2010-11-18 | 2010-12-16 | 188 | 344d | 0d | start no earlier than 2010-07-01 | UHH [166.7%] | 280h |
| 190 | 4.1.4.7 | Integration tests | 6d | 2010-12-17 | 2010-12-24 | 189 | 344d |  | start no earlier than 2010-07-01 | ICS PAS [416.7%] | 200h |
| 191 | 4.1.5 | **Integration of the chain for Greek** | 307d? | 2010-07-01 | 2011-09-02 |  | 164d | 0d |  | Atlantis | 6352h |
| 192 | 4.1.5.1 | Integration of the tokenizer | 1d? | 2010-07-01 | 2010-07-01 |  | 470d |  | start no earlier than 2010-07-01 |  |  |
| 193 | 4.1.5.2 | Integration of the lemmatizer | 1d? | 2010-07-01 | 2010-07-01 |  | 470d |  | start no earlier than 2010-07-01 |  |  |
| 194 | 4.1.5.3 | Integration of the sentence splitter | 84d | 2010-10-01 | 2011-01-26 |  | 321d |  | start no earlier than 2010-10-01 | Atlantis | 672h |
| 195 | 4.1.5.4 | Integration of the POS tagger | 147d | 2010-12-01 | 2011-06-23 |  | 215d |  | start no earlier than 2010-12-01 | Atlantis | 1176h |
| 196 | 4.1.5.5 | Integration of the NP extractor | 1d? | 2010-07-01 | 2010-07-01 |  | 470d |  | start no earlier than 2010-07-01 |  |  |
| 197 | 4.1.5.6 | Integration of the NE recognizer | 147d | 2010-12-01 | 2011-06-23 |  | 215d |  | start no earlier than 2010-12-01 | Atlantis | 1176h |
| 198 | 4.1.5.7 | Testing and re-engineering of the GR LPC tools | 84d | 2011-05-02 | 2011-08-25 |  | 164d | 0d | start no earlier than 2011-05-02 | Atlantis | 672h |
| 199 | 4.1.5.8 | Integration tests | 6d | 2011-08-26 | 2011-09-02 | 198 | 164d |  | start no earlier than 2010-07-01 | ICS PAS [416.7%] | 200h |

| ID | WBS | Task | Duration | Start | Finish | Predecessors | Total slack | Free slack | Constraint | Resources | Work |
| --- | --- | --- | --- | --- | --- | --- | --- | --- | --- | --- | --- |
| 200 | 4.1.6 | **Integration of the chain for Polish** | 135d | 2010-08-11 | 2011-02-15 |  | 307d | 143d |  | ICS PAS | 3680h |
| 201 | 4.1.6.1 | Integration of the tokenizer | 15d | 2010-08-11 | 2010-08-31 | 162 | 307d | 0d | start no earlier than 2010-07-01 | ICS PAS [200%] | 240h |
| 202 | 4.1.6.2 | Integration of the lemmatizer | 20d | 2010-09-01 | 2010-09-28 | 201 | 307d | 0d | start no earlier than 2010-07-01 | ICS PAS [200%] | 320h |
| 203 | 4.1.6.3 | Integration of the sentence splitter | 15d | 2010-09-29 | 2010-10-19 | 202 | 307d | 0d | start no earlier than 2010-07-01 | ICS PAS [200%] | 240h |
| 204 | 4.1.6.4 | Integration of the POS tagger | 15d | 2010-10-20 | 2010-11-09 | 203 | 307d | 0d | start no earlier than 2010-07-01 | ICS PAS [333.3%] | 400h |
| 205 | 4.1.6.5 | Integration of the NP extractor | 20d | 2010-11-10 | 2010-12-07 | 204 | 307d | 0d | start no earlier than 2010-07-01 | ICS PAS [375%] | 600h |
| 206 | 4.1.6.6 | Integration of the NE recognizer | 30d | 2010-12-08 | 2011-01-18 | 205 | 307d | 0d | start no earlier than 2010-07-01 | ICS PAS [250%] | 600h |
| 207 | 4.1.6.7 | Integration tests | 20d | 2011-01-19 | 2011-02-15 | 206 | 307d |  | start no earlier than 2010-07-01 | ICS PAS [125%] | 200h |
| 208 | 4.1.7 | **Integration of the chain for Romanian** | 171d | 2010-07-01 | 2011-02-24 |  | 300d | 136d |  | UAIC | 4144h |
| 209 | 4.1.7.1 | Integration of the tokenizer | 27d | 2010-07-01 | 2010-08-06 |  | 300d | 0d | start no earlier than 2010-07-01 | UAIC [196.3%] | 424h |
| 210 | 4.1.7.2 | Integration of the lemmatizer | 27d | 2010-08-09 | 2010-09-14 | 209 | 300d | 0d | start no earlier than 2010-07-01 | UAIC [196.3%] | 424h |
| 211 | 4.1.7.3 | Integration of the sentence splitter | 27d | 2010-09-15 | 2010-10-21 | 210 | 300d | 0d | start no earlier than 2010-07-01 | UAIC [196.3%] | 424h |
| 212 | 4.1.7.4 | Integration of the POS tagger | 27d | 2010-10-22 | 2010-11-29 | 211 | 300d | 0d | start no earlier than 2010-07-01 | UAIC [196.3%] | 424h |
| 213 | 4.1.7.5 | Integration of the NP extractor | 30d | 2010-11-30 | 2011-01-10 | 212 | 300d | 0d | start no earlier than 2010-07-01 | UAIC [190%] | 456h |
| 214 | 4.1.7.6 | Integration of the NE recognizer | 27d | 2011-01-11 | 2011-02-16 | 213 | 300d | 0d | start no earlier than 2010-07-01 | UAIC [196.3%] | 424h |
| 215 | 4.1.7.7 | Integration tests | 6d | 2011-02-17 | 2011-02-24 | 214 | 300d |  | start no earlier than 2010-07-01 | ICS PAS [416.7%] | 200h |
| 216 | 4.1.8 | Technical review of all LPCs | 10d | 2011-09-05 | 2011-09-16 | 200, 166, 175, 183, 191, 208 | 179d |  |  | IBL DCL | 80h |
| 217 | 4.1.9 | Technical review of all LPCs | 25d? | 2011-09-05 | 2011-10-07 | 200, 166, 175, 183, 191, 208 | 164d | 0d | start no earlier than 2011-02-27 |  |  |
| 218 | 4.2 | **T4.2 Software adjustments (in resp. to technical reviews)** | 29d | 2011-10-10 | 2011-11-17 | 161 | 161d | 0d |  |  | 2288h |
| 219 | 4.2.1 | **Bulgarian LPC** | 26d | 2011-10-10 | 2011-11-14 | 217 | 164d |  |  | IBL DCL | 416h |
| 220 | 4.2.1.1 | Reviewing the produced software components for Bulgarian | 14d | 2011-10-10 | 2011-10-27 |  | 164d | 0d | start no earlier than 2011-10-06 | IBL DCL | 112h |
| 221 | 4.2.1.2 | Adjustment of Bulgarian software components | 12d | 2011-10-28 | 2011-11-14 | 220 | 164d |  | start no earlier than 2011-10-06 | IBL DCL | 96h |
| 222 | 4.2.2 | Croatian LPC | 20d | 2011-10-10 | 2011-11-04 |  | 170d |  |  | UniZD [395%] | 632h |
| 223 | 4.2.3 | German LPC | 9d | 2011-10-10 | 2011-10-20 |  | 181d |  |  | UHH [411.1%] | 296h |
| 224 | 4.2.4 | Greek LPC | 26d | 2011-10-10 | 2011-11-14 |  | 164d |  |  | Atlantis | 208h |
| 225 | 4.2.5 | Romanian LPC | 10d | 2011-10-10 | 2011-10-21 |  | 180d |  |  | UAIC [200%] | 160h |
| 226 | 4.2.6 | Bulgarian LPC | 11d | 2011-10-10 | 2011-10-24 | 217 | 179d |  | start no earlier than 2011-04-03 | Tetracom [109.1%] | 96h |
| 227 | 4.2.7 | Croatian LPC | 11d | 2011-10-12 | 2011-10-26 |  | 177d |  | start no earlier than 2011-10-12 | Tetracom [109.1%] | 96h |
| 228 | 4.2.8 | German LPC | 11d | 2011-10-18 | 2011-11-01 |  | 173d |  | start no earlier than 2011-10-18 | Tetracom [109.1%] | 96h |
| 229 | 4.2.9 | Greek LPC | 11d | 2011-10-24 | 2011-11-07 |  | 169d |  | start no earlier than 2011-10-24 | Tetracom [109.1%] | 96h |
| 230 | 4.2.10 | Polish LPC | 11d | 2011-10-28 | 2011-11-11 |  | 165d |  | start no earlier than 2011-10-28 | Tetracom [109.1%] | 96h |
| 231 | 4.2.11 | Romanian LPC | 11d | 2011-11-03 | 2011-11-17 |  | 161d |  | start no earlier than 2011-11-03 | Tetracom [109.1%] | 96h |

| ID | WBS | Task | Duration | Start | Finish | Predecessors | Total slack | Free slack | Constraint | Resources | Work |
| --- | --- | --- | --- | --- | --- | --- | --- | --- | --- | --- | --- |
| 232 | 4.3 | **T4.3 ATLAS LPC support extension** | 85d | 2010-07-01 | 2010-10-27 |  | 437d | 276d |  |  | 720h |
| 233 | 4.3.1 | ATLAS LPC support extension | 85d | 2010-07-01 | 2010-10-27 |  | 437d | 276d | start no earlier than 2010-07-01 | Tetracom [105.9%] | 720h |
| 234 | 4.4 | **T4.4 Integration of LPCs in ATLAS** | 30d | 2011-11-18 | 2011-12-29 | 218, 232 | 161d | 0d |  |  | 2488h |
| 235 | 4.4.1 | **Bulgarian LPC** | 29d | 2011-11-18 | 2011-12-28 | 233 | 162d |  |  | IBL DCL | 720h |
| 236 | 4.4.1.1 | Integration of Bulgarian LPC in ATLAS | 18d | 2011-11-18 | 2011-12-13 |  | 162d | 0d | start no earlier than 2011-11-18 | IBL DCL [277.8%] | 400h |
| 237 | 4.4.1.2 | Testing and improvement | 11d | 2011-12-14 | 2011-12-28 | 236 | 162d |  |  | IBL DCL | 88h |
| 238 | 4.4.2 | Croatian LPC | 20d | 2011-11-18 | 2011-12-15 |  | 171d |  |  | UniZD [590%] | 944h |
| 239 | 4.4.3 | German LPC | 7d | 2011-11-18 | 2011-11-28 |  | 184d |  |  | UHH [200%] | 112h |
| 240 | 4.4.4 | Greek LPC | 29d | 2011-11-18 | 2011-12-28 |  | 162d |  |  | Atlantis | 232h |
| 241 | 4.4.5 | Bulgarian LPC | 5d | 2011-11-18 | 2011-11-24 | 233 | 161d | 0d | start no earlier than 2011-11-18 | Tetracom [200%] | 80h |
| 242 | 4.4.6 | Croatian LPC | 5d | 2011-11-25 | 2011-12-01 | 241 | 161d | 0d | start no earlier than 2011-05-22 | Tetracom [200%] | 80h |
| 243 | 4.4.7 | German LPC | 5d | 2011-12-02 | 2011-12-08 | 242 | 161d | 0d | start no earlier than 2011-05-22 | Tetracom [200%] | 80h |
| 244 | 4.4.8 | Greek LPC | 5d | 2011-12-09 | 2011-12-15 | 243 | 161d | 0d | start no earlier than 2011-05-22 | Tetracom [200%] | 80h |
| 245 | 4.4.9 | Polish LPC | 5d | 2011-12-16 | 2011-12-22 | 244 | 161d | 0d | start no earlier than 2011-05-22 | Tetracom [200%] | 80h |
| 246 | 4.4.10 | Romanian LPC | 5d | 2011-12-23 | 2011-12-29 | 245 | 161d | 0d | start no earlier than 2011-05-22 | Tetracom [200%] | 80h |
| 247 | 4.5 | **T4.5 Documentation** | 40d | 2011-12-30 | 2012-02-23 | 234 | 266d |  |  |  | 3104h |
| 248 | 4.5.1 | ATLAS technical documentation update | 15d | 2011-12-30 | 2012-01-19 | 246 | 281d | 0d | start no earlier than 2011-11-17 | Tetracom [200%] | 240h |
| 249 | 4.5.2 | ATLAS technical documentation update | 10d | 2011-12-30 | 2012-01-12 |  | 296d |  |  | UniZD [400%] | 320h |
| 250 | 4.5.3 | ATLAS technical documentation update | 16d | 2011-12-30 | 2012-01-20 |  | 290d |  |  | UHH [400%] | 512h |
| 251 | 4.5.4 | **ATLAS technical documentation update** | 30d | 2011-12-30 | 2012-02-09 |  | 276d |  |  | ICS PAS | 680h |
| 252 | 4.5.4.1 | Preparation of the Language Processing Chains documentation | 20d | 2011-12-30 | 2012-01-26 |  | 276d | 0d | start no earlier than 2011-12-01 | ICS PAS [200%] | 320h |
| 253 | 4.5.4.2 | LPC documentation review | 5d | 2012-01-27 | 2012-02-02 | 252 | 276d | 0d |  | ICS PAS [200%] | 80h |
| 254 | 4.5.4.3 | Final version of the LPC documentation | 5d | 2012-02-03 | 2012-02-09 | 253 | 276d |  |  | ICS PAS | 40h |
| 255 | 4.5.5 | ATLAS technical documentation update | 40d | 2011-12-30 | 2012-02-23 |  | 266d |  |  | UAIC [200%] | 640h |
| 256 | 4.5.6 | User guides update | 22d | 2011-12-30 | 2012-01-30 | 246 | 284d |  | start no earlier than 2011-11-17 | Tetracom [200%] | 352h |
| 257 | 4.5.7 | User guides update | 20d | 2011-12-30 | 2012-01-26 |  | 286d |  |  | IBL DCL | 160h |
| 258 | 4.5.8 | Documentation review | 5d | 2012-01-20 | 2012-01-26 | 248 | 286d |  | start no earlier than 2011-11-17 | Tetracom [200%] | 80h |
| 259 | 4.5.9 | Documentation review | 10d | 2012-01-20 | 2012-02-02 | 248 | 281d |  |  | IBL DCL [50%]; UAIC | 120h |

| ID | WBS | Task | Duration | Start | Finish | Predecessors | Total slack | Free slack | Constraint | Resources | Work |
| --- | --- | --- | --- | --- | --- | --- | --- | --- | --- | --- | --- |
| 260 | 5 | **WP5 - Text Summarization** | 422d? | 2011-01-07 | 2012-08-20 | 47 | 139d |  |  |  | 33792h |
| 261 | 5.1 | **T5.1 Implementation of text summarization tools** | 325d? | 2011-01-07 | 2012-04-05 |  | 57d | 0d |  |  | 28312h |
| 262 | 5.1.1 | **Bulgarian summarization tool (incl. documentation)** | 259d | 2011-03-03 | 2012-02-28 |  | 84d |  |  | IBL DCL | 4512h |
| 263 | 5.1.1.1 | Experimenting the “baseline” system | 4d | 2011-03-03 | 2011-03-08 |  | 323d | 0d | start no earlier than 2011-03-03 | IBL DCL [200%] | 64h |
| 264 | 5.1.1.2 | Preparation of the language dependent components: tokenizer, POS-tagger, NP-chunker, sentence and clause splitters | 4d | 2011-03-09 | 2011-03-14 | 263 | 323d | 0d |  | IBL DCL [200%] | 64h |
| 265 | 5.1.1.3 | Runs with the processing chains for English | 4d | 2011-03-15 | 2011-03-18 | 264 | 323d | 0d |  | IBL DCL [200%] | 64h |
| 266 | 5.1.1.4 | Syntactic parser, NER | 4d | 2011-03-21 | 2011-03-24 | 265 | 323d | 0d |  | IBL DCL [200%] | 64h |
| 267 | 5.1.1.5 | Study the RARE documentation and card code | 4d | 2011-03-25 | 2011-03-30 | 266 | 323d |  |  | IBL DCL [200%] | 64h |
| 268 | 5.1.1.6 | Assembling of the chain C1: (text) - tokenizer - POS tagger - NP chunker - (XML) | 21d | 2011-04-01 | 2011-04-29 |  | 301d |  | start no earlier than 2011-04-01 | IBL DCL [57.1%] | 96h |
| 269 | 5.1.1.7 | Assembling of the chain C2: (text) - sentence splitter - clause splitter - (XML) | 21d | 2011-04-01 | 2011-04-29 |  | 301d |  | start no earlier than 2011-04-01 | IBL DCL [57.1%] | 96h |
| 270 | 5.1.1.8 | Integration of RARE equipped with the minimal set of heuristics/rules at the end of chain C1: chain C1.1-v0 = C1 (XML) - RARE - XML | 22d | 2011-05-02 | 2011-05-31 |  | 279d |  | start no earlier than 2011-05-02 | IBL DCL [54.5%] | 96h |
| 271 | 5.1.1.9 | Programming testing chain C1.1-v0 | 22d | 2011-05-02 | 2011-05-31 |  | 279d |  | start no earlier than 2011-05-02 | IBL DCL [54.5%] | 96h |
| 272 | 5.1.1.10 | Creation of the gold corpora for testing C1 (GC1) | 22d | 2011-06-01 | 2011-06-30 |  | 257d |  | start no earlier than 2011-06-01 | IBL DCL [54.5%] | 96h |
| 273 | 5.1.1.11 | Creation of the gold corpora for testing C1.1 (GC1.1) | 22d | 2011-06-01 | 2011-06-30 |  | 257d |  | start no earlier than 2011-06-01 | IBL DCL [54.5%] | 96h |
| 274 | 5.1.1.12 | Evaluation of C1 against GC1 | 22d | 2011-06-01 | 2011-06-30 |  | 257d |  | start no earlier than 2011-06-01 | IBL DCL [22.7%] | 40h |
| 275 | 5.1.1.13 | Evaluation of C1.1 against GC1.1 | 22d | 2011-06-01 | 2011-06-30 |  | 257d |  | start no earlier than 2011-06-01 | IBL DCL [22.7%] | 40h |
| 276 | 5.1.1.14 | Enhancing the resource R1 - R1-v1 | 21d | 2011-07-01 | 2011-07-29 |  | 236d |  | start no earlier than 2011-07-01 | IBL DCL [57.1%] | 96h |
| 277 | 5.1.1.15 | Integration of R1-v1 in RARE and C1.1 - C1.1-v1 | 21d | 2011-07-01 | 2011-07-29 |  | 236d |  | start no earlier than 2011-07-01 | IBL DCL [57.1%] | 96h |
| 278 | 5.1.1.16 | Evaluation of C1.1-v1 | 21d | 2011-07-01 | 2011-07-29 |  | 236d |  | start no earlier than 2011-07-01 | IBL DCL [23.8%] | 40h |
| 279 | 5.1.1.17 | Creation of the first version of R2 - R2-v0 | 23d | 2011-08-01 | 2011-08-31 |  | 213d |  | start no earlier than 2011-08-01 | IBL DCL [52.2%] | 96h |
| 280 | 5.1.1.18 | Integration of edts-builder equipped with R2-v0 at the end of chain C2: chain C2.1-v0 = C2 (XML) - edts-builder (equipped with R2-v0) - (XML) | 23d | 2011-08-01 | 2011-08-31 |  | 213d |  | start no earlier than 2011-08-01 | IBL DCL [52.2%] | 96h |
| 281 | 5.1.1.19 | Creation of the gold corpora for testing C2 (GC2) | 22d | 2011-09-01 | 2011-09-30 |  | 191d |  | start no earlier than 2011-09-01 | IBL DCL [54.5%] | 96h |
| 282 | 5.1.1.20 | Creation of the gold corpora for testing C2.1 (GC2.1) | 22d | 2011-09-01 | 2011-09-30 |  | 191d |  | start no earlier than 2011-09-01 | IBL DCL [54.5%] | 96h |
| 283 | 5.1.1.21 | Evaluation of C2 against GC2 | 22d | 2011-09-01 | 2011-09-30 |  | 191d |  | start no earlier than 2011-09-01 | IBL DCL [22.7%] | 40h |
| 284 | 5.1.1.22 | Evaluation of C2.1-v0 against GC2.1 | 22d | 2011-09-01 | 2011-09-30 |  | 191d |  | start no earlier than 2011-09-01 | IBL DCL [22.7%] | 40h |
| 285 | 5.1.1.23 | Merging C1.1 and C2.1 and coupling to the discourse parser - chain C3 (proposal for versioning of chain C3: v<x><y>, where <x>=R1 version, <y>=R2 version) | 21d | 2011-10-03 | 2011-10-31 |  | 170d |  | start no earlier than 2011-10-03 | IBL DCL [57.1%] | 96h |
| 286 | 5.1.1.24 | Integration of the summarization module - chain C4 (proposal for versioning chain C4: v<x><y><z>, where <z>=R3 version – the parametrizing version of the discourse parser) | 21d | 2011-10-03 | 2011-10-31 |  | 170d |  | start no earlier than 2011-10-03 | IBL DCL [57.1%] | 96h |
| 287 | 5.1.1.25 | Program testing the chain C4-v1.0.0 - first summaries | 21d | 2011-10-03 | 2011-10-31 |  | 170d |  | start no earlier than 2011-10-03 | IBL DCL [57.1%] | 96h |
| 288 | 5.1.1.26 | Quality testing (evaluation) and enhancement of the chain C4 (which, optionally, could include the creation of a gold corpus of summaries: GC4) | 86d | 2011-11-01 | 2012-02-28 |  | 84d |  | start no earlier than 2011-11-01 | IBL DCL [34.9%] | 240h |
| 289 | 5.1.1.27 | Enhancing processing speed | 86d | 2011-11-01 | 2012-02-28 |  | 84d |  | start no earlier than 2011-11-01 | IBL DCL [34.9%] | 240h |

| ID | WBS | Task | Duration | Start | Finish | Predecessors | Total slack | Free slack | Constraint | Resources | Work |
| --- | --- | --- | --- | --- | --- | --- | --- | --- | --- | --- | --- |
| 290 | 5.1.2 | **Croatian summarization tool (incl. documentation)** | 263d | 2011-02-25 | 2012-02-28 |  | 84d |  |  | UniZD | 5856h |
| 291 | 5.1.2.1 | Experimenting the “baseline” system | 5d | 2011-02-25 | 2011-03-03 |  | 322d | 0d | start no earlier than 2011-02-25 | UniZD [200%] | 80h |
| 292 | 5.1.2.2 | Preparation of the language dependent components: tokenizer, POS-tagger, NP-chunker, sentence and clause splitters | 5d | 2011-03-04 | 2011-03-10 | 291 | 322d | 0d |  | UniZD [200%] | 80h |
| 293 | 5.1.2.3 | Runs with the processing chains for English | 5d | 2011-03-11 | 2011-03-17 | 292 | 322d | 0d |  | UniZD [200%] | 80h |
| 294 | 5.1.2.4 | Syntactic parser, NER | 5d | 2011-03-18 | 2011-03-24 | 293 | 322d | 0d |  | UniZD [200%] | 80h |
| 295 | 5.1.2.5 | Study the RARE documentation and card code | 5d | 2011-03-25 | 2011-03-31 | 294 | 322d |  |  | UniZD [200%] | 80h |
| 296 | 5.1.2.6 | Assembling of the chain C1: (text) - tokenizer - POS tagger - NP chunker - (XML) | 21d | 2011-04-01 | 2011-04-29 |  | 301d |  | start no earlier than 2011-04-01 | UniZD | 168h |
| 297 | 5.1.2.7 | Assembling of the chain C2: (text) - sentence splitter - clause splitter - (XML) | 21d | 2011-04-01 | 2011-04-29 |  | 301d |  | start no earlier than 2011-04-01 | UniZD | 168h |
| 298 | 5.1.2.8 | Integration of RARE equipped with the minimal set of heuristics/rules at the end of chain C1: chain C1.1-v0 = C1 (XML) - RARE - XML | 22d | 2011-05-02 | 2011-05-31 |  | 279d |  | start no earlier than 2011-05-02 | UniZD [90.9%] | 160h |
| 299 | 5.1.2.9 | Programming testing chain C1.1-v0 | 22d | 2011-05-02 | 2011-05-31 |  | 279d |  | start no earlier than 2011-05-02 | UniZD [90.9%] | 160h |
| 300 | 5.1.2.10 | Creation of the gold corpora for testing C1 (GC1) | 22d | 2011-06-01 | 2011-06-30 |  | 257d |  | start no earlier than 2011-06-01 | UniZD | 176h |
| 301 | 5.1.2.11 | Creation of the gold corpora for testing C1.1 (GC1.1) | 22d | 2011-06-01 | 2011-06-30 |  | 257d |  | start no earlier than 2011-06-01 | UniZD | 176h |
| 302 | 5.1.2.12 | Evaluation of C1 against GC1 | 22d | 2011-06-01 | 2011-06-30 |  | 257d |  | start no earlier than 2011-06-01 | UniZD [22.7%] | 40h |
| 303 | 5.1.2.13 | Evaluation of C1.1 against GC1.1 | 22d | 2011-06-01 | 2011-06-30 |  | 257d |  | start no earlier than 2011-06-01 | UniZD [22.7%] | 40h |
| 304 | 5.1.2.14 | Enhancing the resource R1 - R1-v1 | 21d | 2011-07-01 | 2011-07-29 |  | 236d |  | start no earlier than 2011-07-01 | UniZD [95.2%] | 160h |
| 305 | 5.1.2.15 | Integration of R1-v1 in RARE and C1.1 - C1.1-v1 | 21d | 2011-07-01 | 2011-07-29 |  | 236d |  | start no earlier than 2011-07-01 | UniZD [95.2%] | 160h |
| 306 | 5.1.2.16 | Evaluation of C1.1-v1 | 21d | 2011-07-01 | 2011-07-29 |  | 236d |  | start no earlier than 2011-07-01 | UniZD [23.8%] | 40h |
| 307 | 5.1.2.17 | Creation of the first version of R2 - R2-v0 | 23d | 2011-08-01 | 2011-08-31 |  | 213d |  | start no earlier than 2011-08-01 | UniZD [95.7%] | 176h |
| 308 | 5.1.2.18 | Integration of edts-builder equipped with R2-v0 at the end of chain C2: chain C2.1-v0 = C2 (XML) - edts-builder (equipped with R2-v0) - (XML) | 23d | 2011-08-01 | 2011-08-31 |  | 213d |  | start no earlier than 2011-08-01 | UniZD [95.7%] | 176h |
| 309 | 5.1.2.19 | Creation of the gold corpora for testing C2 (GC2) | 22d | 2011-09-01 | 2011-09-30 |  | 191d |  | start no earlier than 2011-09-01 | UniZD | 176h |
| 310 | 5.1.2.20 | Creation of the gold corpora for testing C2.1 (GC2.1) | 22d | 2011-09-01 | 2011-09-30 |  | 191d |  | start no earlier than 2011-09-01 | UniZD | 176h |
| 311 | 5.1.2.21 | Evaluation of C2 against GC2 | 22d | 2011-09-01 | 2011-09-30 |  | 191d |  | start no earlier than 2011-09-01 | UniZD [22.7%] | 40h |
| 312 | 5.1.2.22 | Evaluation of C2.1-v0 against GC2.1 | 22d | 2011-09-01 | 2011-09-30 |  | 191d |  | start no earlier than 2011-09-01 | UniZD [22.7%] | 40h |
| 313 | 5.1.2.23 | Merging C1.1 and C2.1 and coupling to the discourse parser - chain C3 (proposal for versioning of chain C3: v<x><y>, where <x>=R1 version, <y>=R2 version) | 21d | 2011-10-03 | 2011-10-31 |  | 170d |  | start no earlier than 2011-10-03 | UniZD [95.2%] | 160h |
| 314 | 5.1.2.24 | Integration of the summarization module - chain C4 (proposal for versioning chain C4: v<x><y><z>, where <z>=R3 version – the parametrizing version of the discourse parser) | 21d | 2011-10-03 | 2011-10-31 |  | 170d |  | start no earlier than 2011-10-03 | UniZD [95.2%] | 160h |
| 315 | 5.1.2.25 | Program testing the chain C4-v1.0.0 - first summaries | 21d | 2011-10-03 | 2011-10-31 |  | 170d |  | start no earlier than 2011-10-03 | UniZD [95.2%] | 160h |
| 316 | 5.1.2.26 | Quality testing (evaluation) and enhancement of the chain C4 (which, optionally, could include the creation of a gold corpus of summaries: GC4) | 86d | 2011-11-01 | 2012-02-28 |  | 84d |  | start no earlier than 2011-11-01 | UniZD [46.5%] | 320h |
| 317 | 5.1.2.27 | Enhancing processing speed | 86d | 2011-11-01 | 2012-02-28 |  | 84d |  | start no earlier than 2011-11-01 | UniZD [46.5%] | 320h |

| ID | WBS | Task | Duration | Start | Finish | Predecessors | Total slack | Free slack | Constraint | Resources | Work |
| --- | --- | --- | --- | --- | --- | --- | --- | --- | --- | --- | --- |
| 318 | 5.1.3 | **German summarization tool (incl. documentation)** | 248d | 2011-03-18 | 2012-02-28 |  | 84d |  |  | UHH | 2808h |
| 319 | 5.1.3.1 | Experimenting the “baseline” system | 1d | 2011-03-18 | 2011-03-18 |  | 327d | 0d | start no earlier than 2011-03-18 | UHH | 8h |
| 320 | 5.1.3.2 | Preparation of the language dependent components: tokenizer, POS-tagger, NP-chunker, sentence and clause splitters | 1d | 2011-03-21 | 2011-03-21 | 319 | 327d | 0d |  | UHH | 8h |
| 321 | 5.1.3.3 | Runs with the processing chains for English | 1d | 2011-03-22 | 2011-03-22 | 320 | 327d | 0d |  | UHH | 8h |
| 322 | 5.1.3.4 | Syntactic parser, NER | 1d | 2011-03-23 | 2011-03-23 | 321 | 327d | 0d |  | UHH | 8h |
| 323 | 5.1.3.5 | Study the RARE documentation and card code | 1d | 2011-03-24 | 2011-03-24 | 322 | 327d |  |  | UHH | 8h |
| 324 | 5.1.3.6 | Assembling of the chain C1: (text) - tokenizer - POS tagger - NP chunker - (XML) | 21d | 2011-04-01 | 2011-04-29 |  | 301d |  | start no earlier than 2011-04-01 | UHH [19%] | 32h |
| 325 | 5.1.3.7 | Assembling of the chain C2: (text) - sentence splitter - clause splitter - (XML) | 21d | 2011-04-01 | 2011-04-29 |  | 301d |  | start no earlier than 2011-04-01 | UHH [19%] | 32h |
| 326 | 5.1.3.8 | Integration of RARE equipped with the minimal set of heuristics/rules at the end of chain C1: chain C1.1-v0 = C1 (XML) - RARE - XML | 22d | 2011-05-02 | 2011-05-31 |  | 279d |  | start no earlier than 2011-05-02 | UHH [18.2%] | 32h |
| 327 | 5.1.3.9 | Programming testing chain C1.1-v0 | 22d | 2011-05-02 | 2011-05-31 |  | 279d |  | start no earlier than 2011-05-02 | UHH [18.2%] | 32h |
| 328 | 5.1.3.10 | Creation of the gold corpora for testing C1 (GC1) | 22d | 2011-06-01 | 2011-06-30 |  | 257d |  | start no earlier than 2011-06-01 | UHH [22.7%] | 40h |
| 329 | 5.1.3.11 | Creation of the gold corpora for testing C1.1 (GC1.1) | 22d | 2011-06-01 | 2011-06-30 |  | 257d |  | start no earlier than 2011-06-01 | UHH [22.7%] | 40h |
| 330 | 5.1.3.12 | Evaluation of C1 against GC1 | 22d | 2011-06-01 | 2011-06-30 |  | 257d |  | start no earlier than 2011-06-01 | UHH [4.5%] | 8h |
| 331 | 5.1.3.13 | Evaluation of C1.1 against GC1.1 | 22d | 2011-06-01 | 2011-06-30 |  | 257d |  | start no earlier than 2011-06-01 | UHH [4.5%] | 8h |
| 332 | 5.1.3.14 | Enhancing the resource R1 - R1-v1 | 21d | 2011-07-01 | 2011-07-29 |  | 236d |  | start no earlier than 2011-07-01 | UHH [19%] | 32h |
| 333 | 5.1.3.15 | Integration of R1-v1 in RARE and C1.1 - C1.1-v1 | 21d | 2011-07-01 | 2011-07-29 |  | 236d |  | start no earlier than 2011-07-01 | UHH [19%] | 32h |
| 334 | 5.1.3.16 | Evaluation of C1.1-v1 | 21d | 2011-07-01 | 2011-07-29 |  | 236d |  | start no earlier than 2011-07-01 | UHH [4.8%] | 8h |
| 335 | 5.1.3.17 | Creation of the first version of R2 - R2-v0 | 23d | 2011-08-01 | 2011-08-31 |  | 213d |  | start no earlier than 2011-08-01 | UHH [17.4%] | 32h |
| 336 | 5.1.3.18 | Integration of edts-builder equipped with R2-v0 at the end of chain C2: chain C2.1-v0 = C2 (XML) - edts-builder (equipped with R2-v0) - (XML) | 23d | 2011-08-01 | 2011-08-31 |  | 213d |  | start no earlier than 2011-08-01 | UHH [17.4%] | 32h |
| 337 | 5.1.3.19 | Creation of the gold corpora for testing C2 (GC2) | 22d | 2011-09-01 | 2011-09-30 |  | 191d |  | start no earlier than 2011-09-01 | UHH [22.7%] | 40h |
| 338 | 5.1.3.20 | Creation of the gold corpora for testing C2.1 (GC2.1) | 22d | 2011-09-01 | 2011-09-30 |  | 191d |  | start no earlier than 2011-09-01 | UHH [22.7%] | 40h |
| 339 | 5.1.3.21 | Evaluation of C2 against GC2 | 22d | 2011-09-01 | 2011-09-30 |  | 191d |  | start no earlier than 2011-09-01 | UHH [4.5%] | 8h |
| 340 | 5.1.3.22 | Evaluation of C2.1-v0 against GC2.1 | 22d | 2011-09-01 | 2011-09-30 |  | 191d |  | start no earlier than 2011-09-01 | UHH [4.5%] | 8h |
| 341 | 5.1.3.23 | Merging C1.1 and C2.1 and coupling to the discourse parser - chain C3 (proposal for versioning of chain C3: v<x><y>, where <x>=R1 version, <y>=R2 version) | 21d | 2011-10-03 | 2011-10-31 |  | 170d |  | start no earlier than 2011-10-03 | UHH [14.3%] | 24h |
| 342 | 5.1.3.24 | Integration of the summarization module - chain C4 (proposal for versioning chain C4: v<x><y><z>, where <z>=R3 version – the parametrizing version of the discourse parser) | 21d | 2011-10-03 | 2011-10-31 |  | 170d |  | start no earlier than 2011-10-03 | UHH [19%] | 32h |
| 343 | 5.1.3.25 | Program testing the chain C4-v1.0.0 - first summaries | 21d | 2011-10-03 | 2011-10-31 |  | 170d |  | start no earlier than 2011-10-03 | UHH [19%] | 32h |
| 344 | 5.1.3.26 | Quality testing (evaluation) and enhancement of the chain C4 (which, optionally, could include the creation of a gold corpus of summaries: GC4) | 86d | 2011-11-01 | 2012-02-28 |  | 84d |  | start no earlier than 2011-11-01 | UHH [17.4%] | 120h |
| 345 | 5.1.3.27 | Enhancing processing speed | 86d | 2011-11-01 | 2012-02-28 |  | 84d |  | start no earlier than 2011-11-01 | UHH [17.4%] | 120h |

| ID | WBS | Task | Duration | Start | Finish | Predecessors | Total slack | Free slack | Constraint | Resources | Work |
| --- | --- | --- | --- | --- | --- | --- | --- | --- | --- | --- | --- |
| 346 | 5.1.4 | **Greek summarization tool (incl. documentation)** | 259d | 2011-03-03 | 2012-02-28 |  | 84d |  |  | Atlantis | 4024h |
| 347 | 5.1.4.1 | Experimenting the “baseline” system | 4d | 2011-03-03 | 2011-03-08 |  | 323d | 0d | start no earlier than 2011-03-03 | Atlantis | 32h |
| 348 | 5.1.4.2 | Preparation of the language dependent components: tokenizer, POS-tagger, NP-chunker, sentence and clause splitters | 4d | 2011-03-09 | 2011-03-14 | 347 | 323d | 0d |  | Atlantis | 32h |
| 349 | 5.1.4.3 | Runs with the processing chains for English | 4d | 2011-03-15 | 2011-03-18 | 348 | 323d | 0d |  | Atlantis | 32h |
| 350 | 5.1.4.4 | Syntactic parser, NER | 4d | 2011-03-21 | 2011-03-24 | 349 | 323d | 0d |  | Atlantis | 32h |
| 351 | 5.1.4.5 | Study the RARE documentation and card code | 4d | 2011-03-25 | 2011-03-30 | 350 | 323d |  |  | Atlantis | 32h |
| 352 | 5.1.4.6 | Assembling of the chain C1: (text) - tokenizer - POS tagger - NP chunker - (XML) | 21d | 2011-04-01 | 2011-04-29 |  | 301d |  | start no earlier than 2011-04-01 | Atlantis [52.4%] | 88h |
| 353 | 5.1.4.7 | Assembling of the chain C2: (text) - sentence splitter - clause splitter - (XML) | 21d | 2011-04-01 | 2011-04-29 |  | 301d |  | start no earlier than 2011-04-01 | Atlantis [52.4%] | 88h |
| 354 | 5.1.4.8 | Integration of RARE equipped with the minimal set of heuristics/rules at the end of chain C1: chain C1.1-v0 = C1 (XML) - RARE - XML | 22d | 2011-05-02 | 2011-05-31 |  | 279d |  | start no earlier than 2011-05-02 | Atlantis [50%] | 88h |
| 355 | 5.1.4.9 | Programming testing chain C1.1-v0 | 22d | 2011-05-02 | 2011-05-31 |  | 279d |  | start no earlier than 2011-05-02 | Atlantis [50%] | 88h |
| 356 | 5.1.4.10 | Creation of the gold corpora for testing C1 (GC1) | 22d | 2011-06-01 | 2011-06-30 |  | 257d |  | start no earlier than 2011-06-01 | Atlantis [54.5%] | 96h |
| 357 | 5.1.4.11 | Creation of the gold corpora for testing C1.1 (GC1.1) | 22d | 2011-06-01 | 2011-06-30 |  | 257d |  | start no earlier than 2011-06-01 | Atlantis [54.5%] | 96h |
| 358 | 5.1.4.12 | Evaluation of C1 against GC1 | 22d | 2011-06-01 | 2011-06-30 |  | 257d |  | start no earlier than 2011-06-01 | Atlantis [22.7%] | 40h |
| 359 | 5.1.4.13 | Evaluation of C1.1 against GC1.1 | 22d | 2011-06-01 | 2011-06-30 |  | 257d |  | start no earlier than 2011-06-01 | Atlantis [22.7%] | 40h |
| 360 | 5.1.4.14 | Enhancing the resource R1 - R1-v1 | 21d | 2011-07-01 | 2011-07-29 |  | 236d |  | start no earlier than 2011-07-01 | Atlantis [52.4%] | 88h |
| 361 | 5.1.4.15 | Integration of R1-v1 in RARE and C1.1 - C1.1-v1 | 21d | 2011-07-01 | 2011-07-29 |  | 236d |  | start no earlier than 2011-07-01 | Atlantis [52.4%] | 88h |
| 362 | 5.1.4.16 | Evaluation of C1.1-v1 | 21d | 2011-07-01 | 2011-07-29 |  | 236d |  | start no earlier than 2011-07-01 | Atlantis [23.8%] | 40h |
| 363 | 5.1.4.17 | Creation of the first version of R2 - R2-v0 | 23d | 2011-08-01 | 2011-08-31 |  | 213d |  | start no earlier than 2011-08-01 | Atlantis [47.8%] | 88h |
| 364 | 5.1.4.18 | Integration of edts-builder equipped with R2-v0 at the end of chain C2: chain C2.1-v0 = C2 (XML) - edts-builder (equipped with R2-v0) - (XML) | 23d | 2011-08-01 | 2011-08-31 |  | 213d |  | start no earlier than 2011-08-01 | Atlantis [47.8%] | 88h |
| 365 | 5.1.4.19 | Creation of the gold corpora for testing C2 (GC2) | 22d | 2011-09-01 | 2011-09-30 |  | 191d |  | start no earlier than 2011-09-01 | Atlantis [54.5%] | 96h |
| 366 | 5.1.4.20 | Creation of the gold corpora for testing C2.1 (GC2.1) | 22d | 2011-09-01 | 2011-09-30 |  | 191d |  | start no earlier than 2011-09-01 | Atlantis [54.5%] | 96h |
| 367 | 5.1.4.21 | Evaluation of C2 against GC2 | 22d | 2011-09-01 | 2011-09-30 |  | 191d |  | start no earlier than 2011-09-01 | Atlantis [22.7%] | 40h |
| 368 | 5.1.4.22 | Evaluation of C2.1-v0 against GC2.1 | 22d | 2011-09-01 | 2011-09-30 |  | 191d |  | start no earlier than 2011-09-01 | Atlantis [22.7%] | 40h |
| 369 | 5.1.4.23 | Merging C1.1 and C2.1 and coupling to the discourse parser - chain C3 (proposal for versioning of chain C3: v<x><y>, where <x>=R1 version, <y>=R2 version) | 21d | 2011-10-03 | 2011-10-31 |  | 170d |  | start no earlier than 2011-10-03 | Atlantis [52.4%] | 88h |
| 370 | 5.1.4.24 | Integration of the summarization module - chain C4 (proposal for versioning chain C4: v<x><y><z>, where <z>=R3 version – the parametrizing version of the discourse parser) | 21d | 2011-10-03 | 2011-10-31 |  | 170d |  | start no earlier than 2011-10-03 | Atlantis [52.4%] | 88h |
| 371 | 5.1.4.25 | Program testing the chain C4-v1.0.0 - first summaries | 21d | 2011-10-03 | 2011-10-31 |  | 170d |  | start no earlier than 2011-10-03 | Atlantis [52.4%] | 88h |
| 372 | 5.1.4.26 | Quality testing (evaluation) and enhancement of the chain C4 (which, optionally, could include the creation of a gold corpus of summaries: GC4) | 86d | 2011-11-01 | 2012-02-28 |  | 84d |  | start no earlier than 2011-11-01 | Atlantis [17.4%] | 120h |
| 373 | 5.1.4.27 | Enhancing processing speed | 86d | 2011-11-01 | 2012-02-28 |  | 84d |  | start no earlier than 2011-11-01 | Atlantis [17.4%] | 120h |

| ID | WBS | Task | Duration | Start | Finish | Predecessors | Total slack | Free slack | Constraint | Resources | Work |
| --- | --- | --- | --- | --- | --- | --- | --- | --- | --- | --- | --- |
| 374 | 5.1.5 | **Polish summarization tool (incl. documentation)** | 259d | 2011-03-03 | 2012-02-28 |  | 84d |  |  | ICS PAS | 5112h |
| 375 | 5.1.5.1 | Experimenting the “baseline” system | 4d | 2011-03-03 | 2011-03-08 |  | 323d | 0d | start no earlier than 2011-03-03 | ICS PAS [200%] | 64h |
| 376 | 5.1.5.2 | Preparation of the language dependent components: tokenizer, POS-tagger, NP-chunker, sentence and clause splitters | 4d | 2011-03-09 | 2011-03-14 | 375 | 323d | 0d |  | ICS PAS [200%] | 64h |
| 377 | 5.1.5.3 | Runs with the processing chains for English | 4d | 2011-03-15 | 2011-03-18 | 376 | 323d | 0d |  | ICS PAS [200%] | 64h |
| 378 | 5.1.5.4 | Syntactic parser, NER | 4d | 2011-03-21 | 2011-03-24 | 377 | 323d | 0d |  | ICS PAS [200%] | 64h |
| 379 | 5.1.5.5 | Study the RARE documentation and card code | 4d | 2011-03-25 | 2011-03-30 | 378 | 323d |  |  | ICS PAS [200%] | 64h |
| 380 | 5.1.5.6 | Assembling of the chain C1: (text) - tokenizer - POS tagger - NP chunker - (XML) | 21d | 2011-04-01 | 2011-04-29 |  | 301d |  | start no earlier than 2011-04-01 | ICS PAS [81%] | 136h |
| 381 | 5.1.5.7 | Assembling of the chain C2: (text) - sentence splitter - clause splitter - (XML) | 21d | 2011-04-01 | 2011-04-29 |  | 301d |  | start no earlier than 2011-04-01 | ICS PAS [81%] | 136h |
| 382 | 5.1.5.8 | Integration of RARE equipped with the minimal set of heuristics/rules at the end of chain C1: chain C1.1-v0 = C1 (XML) - RARE - XML | 22d | 2011-05-02 | 2011-05-31 |  | 279d |  | start no earlier than 2011-05-02 | ICS PAS [77.3%] | 136h |
| 383 | 5.1.5.9 | Programming testing chain C1.1-v0 | 22d | 2011-05-02 | 2011-05-31 |  | 279d |  | start no earlier than 2011-05-02 | ICS PAS [77.3%] | 136h |
| 384 | 5.1.5.10 | Creation of the gold corpora for testing C1 (GC1) | 22d | 2011-06-01 | 2011-06-30 |  | 257d |  | start no earlier than 2011-06-01 | ICS PAS [77.3%] | 136h |
| 385 | 5.1.5.11 | Creation of the gold corpora for testing C1.1 (GC1.1) | 22d | 2011-06-01 | 2011-06-30 |  | 257d |  | start no earlier than 2011-06-01 | ICS PAS [77.3%] | 136h |
| 386 | 5.1.5.12 | Evaluation of C1 against GC1 | 22d | 2011-06-01 | 2011-06-30 |  | 257d |  | start no earlier than 2011-06-01 | ICS PAS [22.7%] | 40h |
| 387 | 5.1.5.13 | Evaluation of C1.1 against GC1.1 | 22d | 2011-06-01 | 2011-06-30 |  | 257d |  | start no earlier than 2011-06-01 | ICS PAS [22.7%] | 40h |
| 388 | 5.1.5.14 | Enhancing the resource R1 - R1-v1 | 21d | 2011-07-01 | 2011-07-29 |  | 236d |  | start no earlier than 2011-07-01 | ICS PAS [81%] | 136h |
| 389 | 5.1.5.15 | Integration of R1-v1 in RARE and C1.1 - C1.1-v1 | 21d | 2011-07-01 | 2011-07-29 |  | 236d |  | start no earlier than 2011-07-01 | ICS PAS [81%] | 136h |
| 390 | 5.1.5.16 | Evaluation of C1.1-v1 | 21d | 2011-07-01 | 2011-07-29 |  | 236d |  | start no earlier than 2011-07-01 | ICS PAS [23.8%] | 40h |
| 391 | 5.1.5.17 | Creation of the first version of R2 - R2-v0 | 23d | 2011-08-01 | 2011-08-31 |  | 213d |  | start no earlier than 2011-08-01 | ICS PAS [73.9%] | 136h |
| 392 | 5.1.5.18 | Integration of edts-builder equipped with R2-v0 at the end of chain C2: chain C2.1-v0 = C2 (XML) - edts-builder (equipped with R2-v0) - (XML) | 23d | 2011-08-01 | 2011-08-31 |  | 213d |  | start no earlier than 2011-08-01 | ICS PAS [73.9%] | 136h |
| 393 | 5.1.5.19 | Creation of the gold corpora for testing C2 (GC2) | 22d | 2011-09-01 | 2011-09-30 |  | 191d |  | start no earlier than 2011-09-01 | ICS PAS [77.3%] | 136h |
| 394 | 5.1.5.20 | Creation of the gold corpora for testing C2.1 (GC2.1) | 22d | 2011-09-01 | 2011-09-30 |  | 191d |  | start no earlier than 2011-09-01 | ICS PAS [77.3%] | 136h |
| 395 | 5.1.5.21 | Evaluation of C2 against GC2 | 22d | 2011-09-01 | 2011-09-30 |  | 191d |  | start no earlier than 2011-09-01 | ICS PAS [22.7%] | 40h |
| 396 | 5.1.5.22 | Evaluation of C2.1-v0 against GC2.1 | 22d | 2011-09-01 | 2011-09-30 |  | 191d |  | start no earlier than 2011-09-01 | ICS PAS [22.7%] | 40h |
| 397 | 5.1.5.23 | Merging C1.1 and C2.1 and coupling to the discourse parser - chain C3 (proposal for versioning of chain C3: v<x><y>, where <x>=R1 version, <y>=R2 version) | 21d | 2011-10-03 | 2011-10-31 |  | 170d |  | start no earlier than 2011-10-03 | ICS PAS [81%] | 136h |
| 398 | 5.1.5.24 | Integration of the summarization module - chain C4 (proposal for versioning chain C4: v<x><y><z>, where <z>=R3 version – the parametrizing version of the discourse parser) | 21d | 2011-10-03 | 2011-10-31 |  | 170d |  | start no earlier than 2011-10-03 | ICS PAS [81%] | 136h |
| 399 | 5.1.5.25 | Program testing the chain C4-v1.0.0 - first summaries | 21d | 2011-10-03 | 2011-10-31 |  | 170d |  | start no earlier than 2011-10-03 | ICS PAS [81%] | 136h |
| 400 | 5.1.5.26 | Quality testing (evaluation) and enhancement of the chain C4 (which, optionally, could include the creation of a gold corpus of summaries: GC4) | 86d | 2011-11-01 | 2012-02-28 |  | 84d |  | start no earlier than 2011-11-01 | ICS PAS [34.9%] | 240h |
| 401 | 5.1.5.27 | Enhancing processing speed | 86d | 2011-11-01 | 2012-02-28 |  | 84d |  | start no earlier than 2011-11-01 | ICS PAS [34.9%] | 240h |

| ID | WBS | Task | Duration | Start | Finish | Predecessors | Total slack | Free slack | Constraint | Resources | Work |
| --- | --- | --- | --- | --- | --- | --- | --- | --- | --- | --- | --- |
| 402 | 5.1.6 | **Romanian summarization tool (incl. documentation)** | 298d | 2011-01-07 | 2012-02-28 |  | 84d |  |  | UAIC | 5680h |
| 403 | 5.1.6.1 | Experimenting the “baseline” system | 10d | 2011-01-07 | 2011-01-20 |  | 322d | 0d | start no earlier than 2011-01-07 | UAIC | 80h |
| 404 | 5.1.6.2 | Preparation of the language dependent components: tokenizer, POS-tagger, NP-chunker, sentence and clause splitters | 10d | 2011-01-21 | 2011-02-03 | 403 | 322d | 0d |  | UAIC | 80h |
| 405 | 5.1.6.3 | Runs with the processing chains for English | 10d | 2011-02-04 | 2011-02-17 | 404 | 322d | 0d |  | UAIC | 80h |
| 406 | 5.1.6.4 | Syntactic parser, NER | 10d | 2011-02-18 | 2011-03-03 | 405 | 322d | 0d |  | UAIC | 80h |
| 407 | 5.1.6.5 | Elaborates the RARE documentation, documents the RARE card code, shows demos | 10d | 2011-03-04 | 2011-03-17 | 406 | 322d | 0d |  | UAIC | 80h |
| 408 | 5.1.6.6 | Study the RARE documentation and card code | 10d | 2011-03-18 | 2011-03-31 | 407 | 322d |  |  | UAIC | 80h |
| 409 | 5.1.6.7 | Assembling of the chain C1: (text) - tokenizer - POS tagger - NP chunker - (XML) | 21d | 2011-04-01 | 2011-04-29 |  | 301d |  | start no earlier than 2011-04-01 | UAIC [66.7%] | 112h |
| 410 | 5.1.6.8 | Assembling of the chain C2: (text) - sentence splitter - clause splitter - (XML) | 21d | 2011-04-01 | 2011-04-29 |  | 301d |  | start no earlier than 2011-04-01 | UAIC [66.7%] | 112h |
| 411 | 5.1.6.9 | Integration of RARE equipped with the minimal set of heuristics/rules at the end of chain C1: chain C1.1-v0 = C1 (XML) - RARE - XML | 22d | 2011-05-02 | 2011-05-31 |  | 279d |  | start no earlier than 2011-05-02 | UAIC [59.1%] | 104h |
| 412 | 5.1.6.10 | Programming testing chain C1.1-v0 | 22d | 2011-05-02 | 2011-05-31 |  | 279d |  | start no earlier than 2011-05-02 | UAIC [59.1%] | 104h |
| 413 | 5.1.6.11 | Assistance for the creation of chain C1.1-v0 | 22d | 2011-05-02 | 2011-05-31 |  | 279d |  | start no earlier than 2011-05-02 | UAIC [45.5%] | 80h |
| 414 | 5.1.6.12 | Creation of the gold corpora for testing C1 (GC1) | 22d | 2011-06-01 | 2011-06-30 |  | 257d |  | start no earlier than 2011-06-01 | UAIC [59.1%] | 104h |
| 415 | 5.1.6.13 | Creation of the gold corpora for testing C1.1 (GC1.1) | 22d | 2011-06-01 | 2011-06-30 |  | 257d |  | start no earlier than 2011-06-01 | UAIC [59.1%] | 104h |
| 416 | 5.1.6.14 | Evaluation of C1 against GC1 | 22d | 2011-06-01 | 2011-06-30 |  | 257d |  | start no earlier than 2011-06-01 | UAIC [22.7%] | 40h |
| 417 | 5.1.6.15 | Evaluation of C1.1 against GC1.1 | 22d | 2011-06-01 | 2011-06-30 |  | 257d |  | start no earlier than 2011-06-01 | UAIC [22.7%] | 40h |
| 418 | 5.1.6.16 | Assistance for the creation of GCs and evaluation | 22d | 2011-06-01 | 2011-06-30 |  | 257d |  | start no earlier than 2011-06-01 | UAIC [45.5%] | 80h |
| 419 | 5.1.6.17 | Enhancing the resource R1 - R1-v1 | 21d | 2011-07-01 | 2011-07-29 |  | 236d |  | start no earlier than 2011-07-01 | UAIC [61.9%] | 104h |
| 420 | 5.1.6.18 | Assistance for enhancing R1 | 21d | 2011-07-01 | 2011-07-29 |  | 236d |  | start no earlier than 2011-07-01 | UAIC [47.6%] | 80h |
| 421 | 5.1.6.19 | Integration of R1-v1 in RARE and C1.1 - C1.1-v1 | 21d | 2011-07-01 | 2011-07-29 |  | 236d |  | start no earlier than 2011-07-01 | UAIC [61.9%] | 104h |
| 422 | 5.1.6.20 | Evaluation of C1.1-v1 | 21d | 2011-07-01 | 2011-07-29 |  | 236d |  | start no earlier than 2011-07-01 | UAIC [23.8%] | 40h |
| 423 | 5.1.6.21 | Assistance for the creation of R1-v1 and evaluation | 21d | 2011-07-01 | 2011-07-29 |  | 236d |  | start no earlier than 2011-07-01 | UAIC [47.6%] | 80h |
| 424 | 5.1.6.22 | Creation of the first version of R2 - R2-v0 | 23d | 2011-08-01 | 2011-08-31 |  | 213d |  | start no earlier than 2011-08-01 | UAIC [56.5%] | 104h |
| 425 | 5.1.6.23 | Integration of edts-builder equipped with R2-v0 at the end of chain C2: chain C2.1-v0 = C2 (XML) - edts-builder (equipped with R2-v0) - (XML) | 23d | 2011-08-01 | 2011-08-31 |  | 213d |  | start no earlier than 2011-08-01 | UAIC [56.5%] | 104h |
| 426 | 5.1.6.24 | Assistance for the creation of chain C2.1-v0 | 23d | 2011-08-01 | 2011-08-31 |  | 213d |  | start no earlier than 2011-08-01 | UAIC [43.5%] | 80h |
| 427 | 5.1.6.25 | Creation of the gold corpora for testing C2 (GC2) | 22d | 2011-09-01 | 2011-09-30 |  | 191d |  | start no earlier than 2011-09-01 | UAIC [59.1%] | 104h |
| 428 | 5.1.6.26 | Creation of the gold corpora for testing C2.1 (GC2.1) | 22d | 2011-09-01 | 2011-09-30 |  | 191d |  | start no earlier than 2011-09-01 | UAIC [59.1%] | 104h |
| 429 | 5.1.6.27 | Evaluation of C2 against GC2 | 22d | 2011-09-01 | 2011-09-30 |  | 191d |  | start no earlier than 2011-09-01 | UAIC [22.7%] | 40h |
| 430 | 5.1.6.28 | Evaluation of C2.1-v0 against GC2.1 | 22d | 2011-09-01 | 2011-09-30 |  | 191d |  | start no earlier than 2011-09-01 | UAIC [22.7%] | 40h |
| 431 | 5.1.6.29 | Assistance for the creation of GCs and evaluation | 22d | 2011-09-01 | 2011-09-30 |  | 191d |  | start no earlier than 2011-09-01 | UAIC [45.5%] | 80h |
| 432 | 5.1.6.30 | Merging C1.1 and C2.1 and coupling to the discourse parser - chain C3 (proposal for versioning of chain C3: v<x><y>, where <x>=R1 version, <y>=R2 version) | 21d | 2011-10-03 | 2011-10-31 |  | 170d |  | start no earlier than 2011-10-03 | UAIC [61.9%] | 104h |
| 433 | 5.1.6.31 | Integration of the summarization module - chain C4 (proposal for versioning chain C4: v<x><y><z>, where <z>=R3 version – the parametrizing version of the discourse parser) | 21d | 2011-10-03 | 2011-10-31 |  | 170d |  | start no earlier than 2011-10-03 | UAIC [61.9%] | 104h |
| 434 | 5.1.6.32 | Program testing the chain C4-v1.0.0 - first summaries | 21d | 2011-10-03 | 2011-10-31 |  | 170d |  | start no earlier than 2011-10-03 | UAIC [61.9%] | 104h |
| 435 | 5.1.6.33 | Assistance | 21d | 2011-10-03 | 2011-10-31 |  | 170d |  | start no earlier than 2011-10-03 | UAIC [47.6%] | 80h |
| 436 | 5.1.6.34 | Quality testing (evaluation) and enhancement of the chain C4 (which, optionally, could include the creation of a gold corpus of summaries: GC4) | 86d | 2011-11-01 | 2012-02-28 |  | 84d |  | start no earlier than 2011-11-01 | UAIC [23.3%] | 160h |
| 437 | 5.1.6.35 | Enhancing processing speed | 86d | 2011-11-01 | 2012-02-28 |  | 84d |  | start no earlier than 2011-11-01 | UAIC [23.3%] | 160h |
| 438 | 5.1.6.36 | Assistance | 86d | 2011-11-01 | 2012-02-28 |  | 84d |  | start no earlier than 2011-11-01 | UAIC [23.3%] | 160h |
| 439 | 5.1.7 | Technical review of all summarization tools | 40d | 2012-02-03 | 2012-03-29 |  | 62d |  | start no earlier than 2012-02-03 | IBL DCL | 320h |
| 440 | 5.1.8 | Technical review of all summarization tools | 45d? | 2012-02-03 | 2012-04-05 |  | 57d | 0d | start no earlier than 2012-02-03 |  |  |

| ID | WBS | Task | Duration | Start | Finish | Predecessors | Total slack | Free slack | Constraint | Resources | Work |
| --- | --- | --- | --- | --- | --- | --- | --- | --- | --- | --- | --- |
| 441 | 5.2 | **T5.2 Software adjustments (in resp. to technical reviews)** | 30d | 2012-04-06 | 2012-05-17 | 261 | 47d | 0d |  |  | 1616h |
| 442 | 5.2.1 | Software adjustments required for the Bulgarian summarization tool | 20d | 2012-04-06 | 2012-05-03 | 440 | 57d |  |  | IBL DCL [400%] | 640h |
| 443 | 5.2.2 | German summarization tool | 9d | 2012-04-06 | 2012-04-18 |  | 68d |  |  | UHH [333.3%] | 240h |
| 444 | 5.2.3 | Romanian summarization tool | 10d | 2012-04-06 | 2012-04-19 |  | 67d |  |  | UAIC [200%] | 160h |
| 445 | 5.2.4 | Bulgarian summarization tool | 7d | 2012-04-11 | 2012-04-19 | 440 | 67d |  | start no earlier than 2012-04-11 | Tetracom [171.4%] | 96h |
| 446 | 5.2.5 | Croatian summarization tool | 7d | 2012-04-17 | 2012-04-25 |  | 63d |  | start no earlier than 2012-04-17 | Tetracom [171.4%] | 96h |
| 447 | 5.2.6 | German summarization tool | 7d | 2012-04-23 | 2012-05-01 |  | 59d |  | start no earlier than 2012-04-23 | Tetracom [171.4%] | 96h |
| 448 | 5.2.7 | Greek summarization tool | 7d | 2012-04-27 | 2012-05-07 |  | 55d |  | start no earlier than 2012-04-27 | Tetracom [171.4%] | 96h |
| 449 | 5.2.8 | Polish summarization tool | 7d | 2012-05-03 | 2012-05-11 |  | 51d |  | start no earlier than 2012-05-03 | Tetracom [171.4%] | 96h |
| 450 | 5.2.9 | Romanian summarization tool | 7d | 2012-05-09 | 2012-05-17 |  | 47d |  | start no earlier than 2012-05-09 | Tetracom [171.4%] | 96h |
| 451 | 5.3 | **T5.3 Integration of summarization tools in ATLAS** | 30d | 2012-05-18 | 2012-06-28 | 441 | 47d | 46d |  |  | 1288h |
| 452 | 5.3.1 | **Bulgarian summarization tool** | 26d | 2012-05-18 | 2012-06-22 |  | 51d |  |  | IBL DCL | 456h |
| 453 | 5.3.1.1 | Integration of Bulgarian summarization tool in ATLAS | 15d | 2012-05-18 | 2012-06-07 |  | 51d | 0d |  | IBL DCL [133.3%] | 160h |
| 454 | 5.3.1.2 | Testing and improvement | 11d | 2012-06-08 | 2012-06-22 | 453 | 51d |  |  | IBL DCL | 88h |
| 455 | 5.3.2 | German summarization tool | 12d | 2012-05-18 | 2012-06-04 |  | 65d |  |  | UHH [200%] | 192h |
| 456 | 5.3.3 | Romanian summarization tool | 10d | 2012-05-18 | 2012-05-31 |  | 67d |  |  | UAIC [200%] | 160h |
| 457 | 5.3.4 | Bulgarian summarization tool | 5d | 2012-05-18 | 2012-05-24 |  | 47d | 0d | start no earlier than 2010-12-26 | Tetracom [200%] | 80h |
| 458 | 5.3.5 | Croatian summarization tool | 5d | 2012-05-25 | 2012-05-31 | 457 | 47d | 0d | start no earlier than 2010-12-26 | Tetracom [200%] | 80h |
| 459 | 5.3.6 | German summarization tool | 5d | 2012-06-01 | 2012-06-07 | 458 | 47d | 0d | start no earlier than 2010-12-26 | Tetracom [200%] | 80h |
| 460 | 5.3.7 | Greek summarization tool | 5d | 2012-06-08 | 2012-06-14 | 459 | 47d | 0d | start no earlier than 2010-12-26 | Tetracom [200%] | 80h |
| 461 | 5.3.8 | Polish summarization tool | 5d | 2012-06-15 | 2012-06-21 | 460 | 47d | 0d | start no earlier than 2010-12-26 | Tetracom [200%] | 80h |
| 462 | 5.3.9 | Romanian summarization tool | 5d | 2012-06-22 | 2012-06-28 | 461 | 47d |  | start no earlier than 2010-12-26 | Tetracom [200%] | 80h |
| 463 | 5.4 | **T5.4 Documentation** | 43d | 2012-06-21 | 2012-08-20 |  | 139d |  |  |  | 2576h |
| 464 | 5.4.1 | ATLAS technical documentation update | 21d | 2012-06-21 | 2012-07-19 |  | 151d | 0d | start no earlier than 2012-06-21 | Tetracom [142.9%] | 240h |
| 465 | 5.4.2 | ATLAS technical documentation update | 10d | 2012-06-21 | 2012-07-04 |  | 172d |  | start no earlier than 2012-06-21 | UniZD [220%] | 176h |
| 466 | 5.4.3 | ATLAS technical documentation update | 16d | 2012-06-21 | 2012-07-12 |  | 166d |  | start no earlier than 2012-06-21 | UHH [300%] | 384h |
| 467 | 5.4.4 | ATLAS technical documentation update | 24d | 2012-06-21 | 2012-07-24 |  | 158d |  | start no earlier than 2012-06-21 | ICS PAS [183.3%] | 352h |
| 468 | 5.4.5 | ATLAS technical documentation update | 40d | 2012-06-21 | 2012-08-15 |  | 142d |  | start no earlier than 2012-06-21 | UAIC [210%] | 672h |
| 469 | 5.4.6 | User guides update | 25d | 2012-07-17 | 2012-08-20 |  | 139d |  | start no earlier than 2012-07-17 | Tetracom [176%] | 352h |
| 470 | 5.4.7 | User guides update | 16d | 2012-07-17 | 2012-08-07 |  | 148d |  | start no earlier than 2012-07-17 | IBL DCL | 128h |
| 471 | 5.4.8 | Documentation review | 10d | 2012-07-20 | 2012-08-02 | 464 | 151d |  | start no earlier than 2012-05-01 | Tetracom | 80h |
| 472 | 5.4.9 | Documentation review | 6d | 2012-07-20 | 2012-07-27 | 464 | 155d |  |  | IBL DCL; UniZD; ICS PAS; UAIC | 192h |

| ID | WBS | Task | Duration | Start | Finish | Predecessors | Total slack | Free slack | Constraint | Resources | Work |
| --- | --- | --- | --- | --- | --- | --- | --- | --- | --- | --- | --- |
| 473 | 6 | **WP6 - Machine Translation and Cross-Lingual Search** | 504d | 2010-08-02 | 2012-07-05 |  | 171d |  |  |  | 22712h |
| 474 | 6.1 | **T6.1 Fine tuning of existing translation models** | 361d | 2010-08-02 | 2011-12-19 |  | 314d |  |  |  | 7552h |
| 475 | 6.1.1 | Collection of monolingual and bilingual corpora to be used | 14d | 2010-08-02 | 2010-08-19 |  | 632d | 0d | start no earlier than 2010-08-02 | IBL DCL; UniZD [427.8%]; UHH; Atlantis; ICS PAS; UAIC; Tetracom [200%] | 1264h |
| 476 | 6.1.2 | Corrections to the Automatic alignment of the parallel resources | 14d | 2010-08-20 | 2010-09-08 | 475 | 632d | 0d |  | IBL DCL; UniZD [428.8%]; UHH; Atlantis; ICS PAS; UAIC; Tetracom [300%] | 1376h |
| 477 | 6.1.3 | Experiments with Moses System for EN-RO, EN-DE-RO and EN-BG, EN-DE-BG : implementation, automatic evaluation, human evaluation | 15d | 2010-09-09 | 2010-09-29 | 476 | 632d |  | start no earlier than 2010-08-02 | UHH [400%]; IBL DCL [200%] | 720h |
| 478 | 6.1.4 | Fine tuning of existing translation models | 60d | 2010-10-01 | 2010-12-23 |  | 400d | 126d | start no earlier than 2010-10-01 | IBL DCL [256.7%] | 1232h |
| 479 | 6.1.5 | **Fine tuning of existing translation models** | 129d | 2010-10-01 | 2011-03-30 |  | 502d |  |  | Atlantis | 1336h |
| 480 | 6.1.5.1 | Identification of model factors that need fine-tuning for GR | 42d | 2010-10-01 | 2010-11-29 |  | 589d |  | start no earlier than 2010-10-01 | Atlantis [45.2%] | 152h |
| 481 | 6.1.5.2 | Testing of the fine-tuned model for GR | 42d | 2011-02-01 | 2011-03-30 |  | 502d |  | start no earlier than 2011-02-01 | Atlantis [45.2%] | 152h |
| 482 | 6.1.6 | Fine tuning of existing translation models | 131d | 2011-06-20 | 2011-12-19 |  | 314d |  | start no earlier than 2011-06-20 | Tetracom [155%] | 1624h |
| 483 | 6.2 | **T6.2 Input data format specification** | 50d | 2011-10-17 | 2011-12-23 |  | 193d | 19d |  |  | 1736h |
| 484 | 6.2.1 | Input data format specification | 50d | 2011-10-17 | 2011-12-23 | 478 | 193d |  | finish no earlier than 2011-12-23 | IBL DCL [340%]; UHH [74%]; UAIC [20%] | 1736h |
| 485 | 6.3 | **T6.3 Implementation of a bridge to EuroMatrix** | 117d | 2012-01-20 | 2012-07-02 | 483 | 174d |  |  |  | 6736.02h |
| 486 | 6.3.1 | Tests of the DFKI Web-Service | 14d | 2012-01-20 | 2012-02-08 |  | 174d | 0d | start no earlier than 2012-01-20 | Tetracom [143%]; IBL DCL [500%]; UniZD; UHH; Atlantis; ICS PAS; UAIC | 1280.02h |
| 487 | 6.3.2 | Choice of best models based on evaluation, implementation MT-Engine Version 1 | 20d | 2012-02-09 | 2012-03-07 | 486 | 174d | 0d |  | UHH [450%]; DFKI [150%] | 960h |
| 488 | 6.3.3 | Evaluation proposals for model refinement | 14d | 2012-03-08 | 2012-03-27 | 487 | 174d | 0d |  | Tetracom [114%]; IBL DCL [464.1%]; UniZD [429%]; UHH; Atlantis; ICS PAS; UAIC | 1576h |
| 489 | 6.3.4 | MT-Engine Update | 20d | 2012-03-28 | 2012-04-24 | 488 | 174d | 0d |  | UHH [300%] | 480h |
| 490 | 6.3.5 | Second Evaluation | 14d | 2012-04-25 | 2012-05-14 | 489 | 174d | 0d |  | Tetracom; IBL DCL [400%]; UniZD; UHH; Atlantis; ICS PAS; UAIC | 1120h |
| 491 | 6.3.6 | Development of an interface for using the MT-system | 20d | 2012-05-15 | 2012-06-11 | 490 | 174d | 0d |  | UHH [300%] | 480h |
| 492 | 6.3.7 | Integration of the system in Tetracom platform | 15d | 2012-06-12 | 2012-07-02 | 491 | 174d |  |  | UHH [200%]; Tetracom [400%]; DFKI | 840h |
| 493 | 6.4 | **T6.4 Cross-lingual Retrieval** | 400d | 2010-12-01 | 2012-06-12 |  | 188d |  |  |  | 5960h |
| 494 | 6.4.1 | Cross-lingual retrieval involving MT | 90d | 2010-12-01 | 2011-04-05 |  | 218d | 0d | start no earlier than 2010-12-01 | UHH [55.6%] | 400h |
| 495 | 6.4.2 | Evaluation | 20d | 2011-04-06 | 2011-05-03 | 494 | 218d | 0d | start no earlier than 2010-12-01 | UHH [50%]; UniZD [200%]; Atlantis [50%]; ICS PAS [50%]; IBL DCL [50%] | 640h |
| 496 | 6.4.3 | Development of lexicons | 70d | 2011-05-04 | 2011-08-09 | 495 | 218d | 0d | start no earlier than 2010-12-01 | UHH [57.2%]; Atlantis [57.2%]; IBL DCL [57.2%]; UAIC [7%]; UniZD; ICS PAS [28.1%] | 1720h |
| 497 | 6.4.4 | Semantic based cross-lingual retrieval | 100d | 2011-08-10 | 2011-12-27 | 496 | 218d | 0d | start no earlier than 2010-12-01 | UHH [50%] | 400h |
| 498 | 6.4.5 | Evaluation | 20d | 2011-12-28 | 2012-01-24 | 497 | 218d | 0d | start no earlier than 2010-12-01 | UHH [50%]; UniZD [200%]; Atlantis [50%]; ICS PAS [50%]; IBL DCL [50%] | 640h |
| 499 | 6.4.6 | Cross-lingual engine Version 2 | 70d | 2012-01-25 | 2012-05-01 | 498 | 218d |  | start no earlier than 2010-12-01 | UHH [50%] | 280h |
| 500 | 6.4.7 | Integration of the cross-lingual search engine in ATLAS | 400d | 2010-12-01 | 2012-06-12 |  | 188d |  | start no earlier than 2010-12-01 | Tetracom [12.7%]; IBL DCL [6.1%]; UHH [40%] | 1880h |

| ID | WBS | Task | Duration | Start | Finish | Predecessors | Total slack | Free slack | Constraint | Resources | Work |
| --- | --- | --- | --- | --- | --- | --- | --- | --- | --- | --- | --- |
| 501 | 6.5 | **T6.5 Documentation** | 48d | 2012-05-01 | 2012-07-05 |  | 171d |  |  |  | 728h |
| 502 | 6.5.1 | ATLAS technical documentation update | 43d | 2012-05-01 | 2012-06-28 |  | 171d | 0d | start no earlier than 2012-05-01 | Tetracom [46.5%]; UHH [79%] | 432h |
| 503 | 6.5.2 | User guides update | 10d | 2012-05-18 | 2012-05-31 |  | 196d |  | start no earlier than 2012-05-18 | Tetracom [200%] | 160h |
| 504 | 6.5.3 | Documentation review | 5d | 2012-06-29 | 2012-07-05 | 502 | 171d |  | start no earlier than 2012-05-01 | Tetracom; IBL DCL [240%] | 136h |
| 505 | 7 | **WP7 - Testing and User Evaluation** | 701d? | 2010-06-24 | 2013-02-28 |  | 1d |  |  |  | 11928h |
| 506 | 7.1 | **T7.1 User evaluation and feedback adjustments** | 607d? | 2010-11-01 | 2013-02-26 |  | 3d |  |  |  | 7912h |
| 507 | 7.1.1 | Definition of qualitative indicators (system availability and response time) | 42d | 2010-11-01 | 2010-12-28 |  | 568d |  | start no earlier than 2010-11-01 | Atlantis [47.6%] | 160h |
| 508 | 7.1.2 | Definition of usability indicators (easy to navigate, clarity in responses, etc.) | 42d | 2010-11-01 | 2010-12-28 |  | 568d |  | start no earlier than 2010-11-01 | Atlantis [47.6%] | 160h |
| 509 | 7.1.3 | Definition of user satisfaction indicators (user satisfaction from different system aspects, user experiences, Uis, etc.) | 42d | 2010-11-01 | 2010-12-28 |  | 568d |  | start no earlier than 2010-11-01 | Atlantis [47.6%] | 160h |
| 510 | 7.1.4 | Compilation of an online user questionnaire (or normal doc questionnaire - to be discussed with ITD) | 42d | 2010-11-01 | 2010-12-28 |  | 568d |  | start no earlier than 2010-11-01 | Atlantis [47.6%] | 160h |
| 511 | 7.1.5 | Compilation of the User Evaluation Plan | 42d | 2010-11-01 | 2010-12-28 |  | 568d |  | start no earlier than 2010-11-01 | Atlantis [47.6%] | 160h |
| 512 | 7.1.6 | User evaluation of ATLAS and the online services after M1 | 42d | 2011-02-17 | 2011-04-15 | 95 | 490d |  | start no earlier than 2010-11-01 | ITD | 336h |
| 513 | 7.1.7 | User evaluation of ATLAS and the online services after M1 | 63d | 2011-02-17 | 2011-05-16 | 95 | 469d |  |  | Atlantis [31.7%] | 160h |
| 514 | 7.1.8 | Feedback adjustments after M1 | 84d? | 2011-03-24 | 2011-07-19 |  | 423d |  | start no earlier than 2011-03-24 | Tetracom [153.6%] | 1032h |
| 515 | 7.1.9 | Feedback adjustments after M1 | 67d | 2011-03-24 | 2011-06-24 |  | 440d |  | start no earlier than 2011-03-24 | Atlantis [29.9%] | 160h |
| 516 | 7.1.10 | Feedback adjustments after M1 | 11d | 2011-03-24 | 2011-04-07 |  | 496d |  | start no earlier than 2011-03-24 | IBL DCL [191.1%]; ICS PAS [254.3%]; UHH [127.1%]; UniZD [227.3%]; UAIC [91.1%] | 784h |
| 517 | 7.1.11 | User evaluation of ATLAS and the online services after M2 | 42d | 2012-01-25 | 2012-03-22 | 153 | 246d |  | start no earlier than 2012-01-25 | ITD | 336h |
| 518 | 7.1.12 | User evaluation of ATLAS and the online services after M2 | 66d | 2012-01-20 | 2012-04-20 | 153 | 225d |  |  | Atlantis [30.3%] | 160h |
| 519 | 7.1.13 | Feedback adjustments after M2 | 80d | 2012-02-29 | 2012-06-19 |  | 183d |  | start no earlier than 2012-02-29 | Tetracom [90%] | 576h |
| 520 | 7.1.14 | Feedback adjustments after M2 | 67d | 2012-02-29 | 2012-05-31 |  | 196d |  | start no earlier than 2012-02-29 | Atlantis [29.9%] | 160h |
| 521 | 7.1.15 | Feedback adjustments after M2 | 12d | 2012-02-29 | 2012-03-15 |  | 251d |  | start no earlier than 2012-02-29 | IBL DCL [175.1%]; ICS PAS [233.2%]; UHH [117.1%]; UniZD [208.2%]; UAIC [83.1%] | 784h |
| 522 | 7.1.16 | User evaluation of ATLAS and the online services after M3 | 42d | 2012-11-01 | 2012-12-28 | 542 | 45d |  | start no earlier than 2012-11-01 | ITD | 336h |
| 523 | 7.1.17 | User evaluation of ATLAS and the online services after M3 | 69d | 2012-10-29 | 2013-01-31 | 542 | 21d |  |  | Atlantis [29%] | 160h |
| 524 | 7.1.18 | Feedback adjustments after M3 | 44d? | 2012-12-27 | 2013-02-26 |  | 3d |  | start no earlier than 2012-12-27 | Tetracom [275%] | 968h |
| 525 | 7.1.19 | Feedback adjustments after M3 | 44d | 2012-12-27 | 2013-02-26 |  | 3d |  | start no earlier than 2012-12-27 | Atlantis [45.5%] | 160h |
| 526 | 7.1.20 | Feedback adjustments after M3 | 26d | 2012-12-27 | 2013-01-31 |  | 21d |  | start no earlier than 2012-12-27 | IBL DCL; ICS PAS; UHH [62%]; UniZD [104%]; UAIC [38%] | 840h |
| 527 | 7.1.21 | Compilation of the User Evaluation Results Report | 511d | 2011-02-17 | 2013-01-31 |  | 21d |  | start no earlier than 2011-02-17 | Atlantis [3.9%] | 160h |

| ID | WBS | Task | Duration | Start | Finish | Predecessors | Total slack | Free slack | Constraint | Resources | Work |
| --- | --- | --- | --- | --- | --- | --- | --- | --- | --- | --- | --- |
| 528 | 7.2 | **T7.2 Testing** | 701d | 2010-06-24 | 2013-02-28 |  | 1d |  |  |  | 3096h |
| 529 | 7.2.1 | Finalisation of KPI (feedback from WP2) | 43d | 2010-06-24 | 2010-08-23 |  | 659d |  | finish no earlier than 2010-08-23 | Atlantis [46.5%] | 160h |
| 530 | 7.2.2 | Definition of Test Cases | 64d | 2010-08-24 | 2010-11-19 |  | 595d |  | finish no earlier than 2010-11-19 | Atlantis [31.2%] | 160h |
| 531 | 7.2.3 | Compilation of the Test Plan | 63d | 2010-11-22 | 2011-02-16 |  | 532d |  | finish no earlier than 2011-02-16 | Atlantis [31.7%] | 160h |
| 532 | 7.2.4 | Testing after M1 | 63d | 2011-02-17 | 2011-05-16 | 95 | 403d | 0d | start no earlier than 2011-02-17 | Atlantis [31.7%] | 160h |
| 533 | 7.2.5 | Addressing of Test Findings after M1 tests | 66d | 2011-05-17 | 2011-08-16 | 532 | 403d |  |  | Atlantis [30.3%] | 160h |
| 534 | 7.2.6 | Testing after M2 | 65d | 2012-01-20 | 2012-04-19 | 153 | 161d | 0d |  | Atlantis [30.8%] | 160h |
| 535 | 7.2.7 | Addressing of Test Findings after M2 tests | 65d | 2012-04-20 | 2012-07-19 | 534 | 161d |  |  | Atlantis [30.8%] | 160h |
| 536 | 7.2.8 | Testing after M3 | 45d | 2012-10-29 | 2012-12-28 | 542 | 1d | 0d |  | Atlantis [44.4%] | 160h |
| 537 | 7.2.9 | Addressing of Test Findings after M3 | 44d | 2012-12-31 | 2013-02-28 | 536 | 1d |  |  | Atlantis [45.5%] | 160h |
| 538 | 7.2.10 | Testing | 673d | 2010-07-01 | 2013-01-28 |  | 24d |  | start no earlier than 2010-07-01 | IBL DCL [1.6%]; UHH [2.2%]; UAIC [1.1%] | 264h |
| 539 | 7.2.11 | Software adjustments | 651d | 2010-08-02 | 2013-01-28 |  | 24d |  | start no earlier than 2010-08-01 | Tetracom [9.2%] | 480h |
| 540 | 7.2.12 | Software adjustments | 651d | 2010-08-02 | 2013-01-28 |  | 24d |  | start no earlier than 2010-08-02 | IBL DCL [9.2%]; UHH [4.2%]; UAIC [1%] | 752h |
| 541 | 7.2.13 | Compilation of the Final Testing Report | 487d | 2011-02-17 | 2012-12-28 |  | 45d |  | start no earlier than 2011-02-17 | Atlantis [4.1%] | 160h |
| 542 | 7.3 | **M3** | 40d | 2012-09-03 | 2012-10-26 | 451 | 1d | 0d |  |  | 920h |
| 543 | 7.3.1 | Launch of the final version of i-Publisher | 20d | 2012-09-03 | 2012-09-28 |  | 1d | 0d | start no earlier than 2012-09-01 | Tetracom [150%] | 240h |
| 544 | 7.3.2 | Launch of the final version of i-Publisher | 6d | 2012-09-03 | 2012-09-10 |  | 35d |  | start no earlier than 2012-09-03 | IBL DCL [82.9%]; UAIC [116.9%]; UHH [66.9%] | 128h |
| 545 | 7.3.3 | Launch of the final version of i-Librarian | 10d | 2012-10-01 | 2012-10-12 | 543 | 1d | 0d | start no earlier than 2012-09-03 | Tetracom [200%] | 160h |
| 546 | 7.3.4 | Launch of the final version of i-Librarian | 5d | 2012-10-01 | 2012-10-05 | 543 | 16d |  |  | IBL DCL; UAIC; UHH [60%] | 104h |
| 547 | 7.3.5 | Launch of the final version of EUDocLib | 10d | 2012-10-15 | 2012-10-26 | 545 | 1d |  | start no earlier than 2012-09-03 | Tetracom [200%] | 160h |
| 548 | 7.3.6 | Launch of the final version of EUDocLib | 7d | 2012-10-15 | 2012-10-23 | 545 | 4d |  |  | IBL DCL; UAIC [85.2%]; UHH [43.1%] | 128h |
| 549 | 8 | **WP8 - Dissemination and Exploitation** | 786d? | 2010-03-01 | 2013-03-01 |  | 0d |  |  |  | 16783.5h |
| 550 | 8.1 | **T8.1 Project web site** | 760d | 2010-04-01 | 2013-02-26 |  | 3d |  |  |  | 2624h |
| 551 | 8.1.1 | Web site public launch | 10d | 2010-04-01 | 2010-04-14 |  | 3d | 0d | start no earlier than 2010-04-01 | Tetracom [300%] | 240h |
| 552 | 8.1.2 | Web site maintenance | 750d | 2010-04-15 | 2013-02-26 | 551 | 3d |  |  | Tetracom [32%] | 1920h |
| 553 | 8.1.3 | Web site maintenance | 750d | 2010-04-15 | 2013-02-26 |  | 3d |  | start no earlier than 2010-04-15 | ITD [2.8%]; UHH [4%]; UAIC [1%] | 464h |

| ID | WBS | Task | Duration | Start | Finish | Predecessors | Total slack | Free slack | Constraint | Resources | Work |
| --- | --- | --- | --- | --- | --- | --- | --- | --- | --- | --- | --- |
| 554 | 8.2 | **T8.2 Detailed Dissemination Plan** | 93d? | 2010-09-01 | 2011-01-07 |  | 455d |  |  |  | 744h |
| 555 | 8.2.1 | Detailed Dissemination Plan | 93d? | 2010-09-01 | 2011-01-07 |  | 455d | 0d | start no earlier than 2010-09-01 | ITD [45.2%] | 336h |
| 556 | 8.2.2 | Detailed Dissemination Plan | 10d | 2010-09-01 | 2010-09-14 |  | 643d |  | start no earlier than 2010-09-01 | IBL DCL; Atlantis [50%]; ICS PAS; UHH; UAIC [160%] | 408h |
| 557 | 8.3 | **T8.3 Sustainability plan preparation** | 740d | 2010-04-01 | 2013-01-29 |  | 23d |  |  |  | 1984h |
| 558 | 8.3.1 | Sustainability Plan draft | 30d | 2010-04-01 | 2010-05-12 |  | 666d | 0d | start no earlier than 2010-04-01 | Tetracom [300%] | 720h |
| 559 | 8.3.2 | Sustainability Plan draft | 21d | 2010-04-01 | 2010-04-29 |  | 742d |  | start no earlier than 2010-04-01 | ITD | 168h |
| 560 | 8.3.3 | Sustainability Plan draft review | 4d | 2010-05-13 | 2010-05-18 | 558 | 666d | 249d | start no earlier than 2010-04-01 | ICS PAS [50%]; UAIC [200%]; UHH | 112h |
| 561 | 8.3.4 | Sustainability Plan update after M1 | 21d | 2011-05-02 | 2011-05-30 | 560, 95 | 417d | 197d | start no earlier than 2011-05-02 | ITD | 168h |
| 562 | 8.3.5 | Sustainability Plan update after M1 | 5d | 2011-05-02 | 2011-05-06 | 95, 560 | 475d |  | start no earlier than 2011-05-01 | Tetracom [300%] | 120h |
| 563 | 8.3.6 | Sustainability Plan update after M2 | 21d | 2012-03-01 | 2012-03-29 | 153, 561 | 220d | 197d | start no earlier than 2012-03-01 | ITD | 168h |
| 564 | 8.3.7 | Sustainability Plan update after M2 | 5d | 2012-03-01 | 2012-03-07 | 153, 561 | 257d |  | start no earlier than 2012-03-01 | Tetracom [300%] | 120h |
| 565 | 8.3.8 | Sustainability Plan update after M3 | 21d | 2013-01-01 | 2013-01-29 | 542, 563 | 23d |  | start no earlier than 2013-01-01 | ITD | 168h |
| 566 | 8.3.9 | Sustainability Plan update after M3 | 10d | 2013-01-01 | 2013-01-14 | 542, 563 | 34d |  | start no earlier than 2013-01-01 | Tetracom [300%] | 240h |
| 567 | 8.4 | **T8.4 Preparation of primary outreach materials** | 105d | 2011-01-10 | 2011-06-03 |  | 455d |  |  |  | 2312h |
| 568 | 8.4.1 | Design of outreach materials | 105d | 2011-01-10 | 2011-06-03 | 555 | 455d |  |  | ITD | 840h |
| 569 | 8.4.2 | Design of outreach materials | 20d | 2011-01-10 | 2011-02-04 | 555 | 540d |  | start no earlier than 2010-07-04 | Tetracom [500%] | 800h |
| 570 | 8.4.3 | Design of outreach materials | 20d | 2011-01-10 | 2011-02-04 | 555 | 540d |  | start no earlier than 2011-01-10 | IBL DCL [200%]; Atlantis [105%]; ICS PAS [50%]; UAIC [25%]; UHH [40%] | 672h |
| 571 | 8.5 | **T8.5 Dissemination of primary materials** | 540d | 2011-02-07 | 2013-03-01 |  | 0d |  |  |  | 1280h |
| 572 | 8.5.1 | Dissemination of primary materials | 540d | 2011-02-07 | 2013-03-01 |  | 0d |  | start no earlier than 2011-02-07 | ITD [7.8%] | 336h |
| 573 | 8.5.2 | Dissemination of primary materials | 540d | 2011-02-07 | 2013-03-01 |  | 0d |  | start no earlier than 2011-02-07 | Tetracom [9.3%] | 400h |
| 574 | 8.5.3 | Dissemination of primary materials | 540d | 2011-02-07 | 2013-03-01 |  | 0d |  | start no earlier than 2011-02-07 | IBL DCL [5.8%]; Atlantis [1%]; ICS PAS [1%]; UAIC [1%]; UniZD [3.9%] | 544h |
| 575 | 8.6 | **T8.6 Interaction with target commmunities** | 715d | 2010-06-01 | 2013-02-22 |  | 5d |  |  |  | 1408h |
| 576 | 8.6.1 | Interaction with target communities | 715d | 2010-06-01 | 2013-02-22 |  | 5d |  | start no earlier than 2010-06-01 | ITD [5.9%] | 336h |
| 577 | 8.6.2 | Interaction with target communities | 715d | 2010-06-01 | 2013-02-22 |  | 5d |  | start no earlier than 2010-06-01 | Tetracom [12.6%] | 720h |
| 578 | 8.6.3 | Interaction with target communities | 715d | 2010-06-01 | 2013-02-22 |  | 5d |  | start no earlier than 2010-06-01 | IBL DCL [3.1%]; Atlantis [1%]; ICS PAS [1%]; UAIC [1%] | 352h |

| ID | WBS | Task | Duration | Start | Finish | Total slack | Constraint | Resources | Work |
| --- | --- | --- | --- | --- | --- | --- | --- | --- | --- |
| 579 | 8.7 | **T8.7 Measurement and evaluation of project impact** | 715d? | 2010-06-01 | 2013-02-22 | 5d |  |  | 3104h |
| 580 | 8.7.1 | Project web site monitoring | 715d? | 2010-06-01 | 2013-02-22 | 5d | start no earlier than 2010-06-01 | ITD [14.7%] | 840h |
| 581 | 8.7.2 | Statistical analysis | 715d | 2010-06-01 | 2013-02-22 | 5d | start no earlier than 2010-06-01 | Tetracom [5.6%] | 320h |
| 582 | 8.7.3 | Statistical analysis | 715d | 2010-06-01 | 2013-02-22 | 5d | start no earlier than 2010-06-01 | IBL DCL [1.4%] | 80h |
| 583 | 8.7.4 | User feedback analysis | 715d | 2010-06-01 | 2013-02-22 | 5d | start no earlier than 2010-06-01 | ITD [17.6%] | 1008h |
| 584 | 8.7.5 | User feedback analysis | 715d | 2010-06-01 | 2013-02-22 | 5d | start no earlier than 2010-06-01 | Tetracom [5%] | 288h |
| 585 | 8.7.6 | User feedback analysis | 715d | 2010-06-01 | 2013-02-22 | 5d | start no earlier than 2010-06-01 | IBL DCL [1.9%]; Atlantis [1.1%]; ICS PAS [1.1%]; UAIC [1.1%]; UHH [1.1%]; UniZD [3.4%] | 568h |
| 586 | 8.8 | **T8.8 Nationwide dissemination** | 715d | 2010-06-01 | 2013-02-22 | 5d |  |  | 1223.53h |
| 587 | 8.8.1 | Exploration of regional networks | 715d | 2010-06-01 | 2013-02-22 | 5d | start no earlier than 2010-06-01 | ITD [1%] | 56h |
| 588 | 8.8.2 | Exploration of regional networks | 715d | 2010-06-01 | 2013-02-22 | 5d | start no earlier than 2010-06-01 | IBL DCL [1.1%]; Atlantis [1.1%]; ICS PAS [1.1%]; UAIC [1.1%]; UHH [1.1%]; UniZD [1.1%] | 368h |
| 589 | 8.8.3 | Participation in national software exhibitions | 715d | 2010-06-01 | 2013-02-22 | 5d | start no earlier than 2010-06-01 | ITD [1%] | 55.77h |
| 590 | 8.8.4 | Participation in national software exhibitions | 715d | 2010-06-01 | 2013-02-22 | 5d | start no earlier than 2010-06-01 | IBL DCL [0.8%]; Atlantis [1.2%]; ICS PAS [2.4%]; UAIC [1.2%]; UHH [1.2%]; UniZD [1.2%] | 464h |
| 591 | 8.8.5 | Organization of community events | 715d | 2010-06-01 | 2013-02-22 | 5d | start no earlier than 2010-06-01 | ITD [1%] | 55.77h |
| 592 | 8.8.6 | Organization of community events | 715d | 2010-06-01 | 2013-02-22 | 5d | start no earlier than 2010-06-01 | IBL DCL [1%]; Atlantis [1.5%]; ICS PAS [1.5%]; UAIC; UHH; UniZD | 224h |
| 593 | 8.9 | **T8.9 Trans-European dissemination** | 513d? | 2010-03-01 | 2012-02-14 | 273d |  |  | 2104h |
| 594 | 8.9.1 | LREC Conference | 5d | 2010-05-19 | 2010-05-25 | 724d | start no earlier than 2010-05-19 | Tetracom | 40h |
| 595 | 8.9.2 | International Event 1 | 5d | 2010-03-01 | 2010-03-05 | 781d |  | IBL DCL [200%] | 80h |
| 596 | 8.9.3 | International Event 2 | 5d | 2010-03-01 | 2010-03-05 | 781d |  | IBL DCL [200%] | 80h |
| 597 | 8.9.4 | International Event 2 | 10d? | 2012-02-01 | 2012-02-14 | 273d | start no earlier than 2012-02-01 |  |  |
| 598 | 8.9.5 | Participation in international software exhibitions | 95d? | 2010-03-01 | 2010-07-08 | 691d | start no earlier than 2010-03-01 | Tetracom | 760h |
| 599 | 8.9.6 | Participation in international software exhibitions | 42d | 2010-03-01 | 2010-04-27 | 744d |  | ITD | 336h |
| 600 | 8.9.7 | Participation in international software exhibitions | 17d | 2010-03-01 | 2010-03-23 | 769d |  | IBL DCL | 136h |
| 601 | 8.9.8 | Participation in international software exhibitions | 29d | 2010-03-01 | 2010-04-08 | 757d |  | UHH | 232h |
| 602 | 8.9.9 | Participation in international software exhibitions | 29d | 2010-03-01 | 2010-04-08 | 757d |  | Atlantis | 232h |
| 603 | 8.9.10 | Participation in international software exhibitions | 5d | 2010-03-01 | 2010-03-05 | 781d |  | ICS PAS | 40h |
| 604 | 8.9.11 | Participation in international software exhibitions | 21d | 2010-03-01 | 2010-03-29 | 765d |  | UAIC | 168h |
